# 3GPP_Work Plan

Schedule from MS Project, 2000-01-03 to 2004-12-31, A marks actual dates.

## Calendars

- Standard: Mon-Fri 08:00-12:00, 13:00-17:00; Sat-Sun off.

## Resources

| Resource |
| --- |
| NP |
| N1 |
| N2 |
| N3 |
| N4 |
| N5 |
| TP |
| T1 |
| T2 |
| T3 |
| RP |
| R1 |
| R2 |
| R3 |
| R4 |
| SP |
| S1 |
| S2 |
| S3 |
| S4 |
| S5 |
| PCG |
| GP |
| No |
| CN4 |
| ? |
| WG G2 |
| G2 |
| G1 |
| G4 |
| G3 |
| All |
| Generic |
| MLST |
| G5 |
| S3, G2 |
| WG T2 |
| GP,G1 |
| G4,G5 |
| OMA |
| GP-G2 |
| Yes |

## Schedule

| ID | WBS | Task | Duration | Start | Finish | Complete | Remaining | Baseline start | Baseline finish | Baseline duration | Total slack | Constraint | Resources | Work | Actual work | Text6 | Text9 | Text1 | Text4 | Text5 | Text7 | Text11 | Text10 | Text2 | Text12 |
| --- | --- | --- | --- | --- | --- | --- | --- | --- | --- | --- | --- | --- | --- | --- | --- | --- | --- | --- | --- | --- | --- | --- | --- | --- | --- |
| 1 | 1 | VERSION 2003 October 15th | 1d | 2000-01-03 | 2000-01-03 |  |  | 2000-01-03 | 2000-01-03 | 1d | 1294d |  |  |  |  | Rel | 2044 |  |  |  |  |  |  |  |  |
| 2 | 2 | "CTRL + a" to display all the 3GPP fields | 1d | 2000-01-03 | 2000-01-03 |  |  | 2000-01-03 | 2000-01-03 | 1d | 1294d |  |  |  |  |  | 1462 |  |  |  |  |  |  |  |  |
| 3 | 3 | Content of Rel-6 and after. Not frozen. | 1d | 2000-01-03 | 2000-01-03 |  |  | 2000-01-03 | 2000-01-03 | 1d | 1294d |  |  |  |  | Rel | 2058 |  |  |  |  |  |  |  |  |
| 5 | 4 | Evolutions of the transport in the UTRAN | 218d | 2003-03-03 | 2003-12-31 |  |  |  |  |  | 252d | start no earlier than 2003-03-03 | RP | 1744h |  | NA | Feat | ETRAN | Francois Courau, Alcatel | francois.courau@alcatel.fr | TSG | Generic |  |  |  |
| 6 | 8 | **Improvements of Radio Interface** | 1001d | 2000-08-14 A | 2004-06-14 | 52% | 476.68d | 2000-08-14 | 2004-03-19 | 940d? | 144d |  | RP | 64064h | 35853.8h | Rel-6 |  | RInImp |  |  | TSG |  |  |  |  |
| 7 | 5.1 | Improvement of inter-frequency and inter-system measurement | 835d | 2001-01-01 A | 2004-03-12 | 10% | 751.5d |  |  |  | 210d | start no earlier than 2001-01-01 | R1 | 6680h | 668h | Rel-6 | BB | RInImp-IfIsM | Antti Toskala, Nokia | antti.toskala@nokia.com | TSG | Active | 1216 |  |  |
| 8 | 5.2 | Improving Receiver Performance Requirements for the FDD UE | 401d | 2002-03-08 A | 2003-09-19 A | 100% |  |  |  |  |  | start no earlier than 2002-03-08 | R4 | 3208h | 3208h | Rel-6 | BB | RInImp-UERecPerf | Shimon Moshavi, Intel | shimon.moshavi@INTEL.COM | TSG | Active | 1216 |  |  |
| 9 | 8.2 | **Base station classification** | 603d | 2000-08-14 A | 2002-12-04 A | 100% |  | 2000-08-14 | 2002-12-04 | 603d |  |  | R4 | 9648h | 9648h | Rel-6 |  | RInImp-BSClass |  |  | TSG |  |  |  |  |
| 10 | 8.2.1 | FDD Base station classification | 603d | 2000-08-14 A | 2002-12-04 A | 100% |  | 2000-08-14 | 2002-12-04 | 603d |  | finish no earlier than 2002-12-04 | R4 | 4824h | 4824h | Rel-6 | 1476 | RInImp-BSClass-FDD | A. Toskala, Nokia |  | TSG |  |  | BaAs |  |
| 11 | 5.4 | UMTS-850 | 331d | 2002-12-06 A | 2004-03-12 | 40% | 198.6d |  |  |  | 210d | start no earlier than 2002-12-06 | R4 | 2648h | 1059.2h | Rel-6 | BB | RInImp-UMTS850 | Don Zelmer, Cingular | don.zelmer@cingular.com | TSG | Active | 1216 |  |  |
| 12 | 5.5 | DS-CDMA introduction in the 800 MHz band | 196d | 2003-03-14 A | 2003-12-12 | 45% | 107.8d |  |  |  | 275d | start no earlier than 2003-03-14 | R4 | 1568h | 705.6h | Rel-6 | BB | RInImp-UMTS800 | Takehiro Nakamura, NTT DoCoMo | takehiro@wsp.yrp.nttdocomo.co.jp | TSG | Active | 1216 |  |  |
| 13 | 5.6 | UMTS 1.7/2.1 GHz | 196d | 2003-03-14 A | 2003-12-12 | 35% | 127.4d |  |  |  | 275d | start no earlier than 2003-03-14 | R4 | 1568h | 548.8h | Rel-6 | BB | RInImp-UMTS1721 | Jussi Numminen, Nokia | jussi.numminen@NOKIA.COM | TSG | Active | 1216 |  |  |
| 14 | 5.7 | FS on Radio link performance enhancements | 940d | 2000-08-14 A | 2004-03-19 | 40% | 564d |  |  |  | 205d | start no earlier than 2000-08-14 | R1 | 7520h | 3008h | Rel-6 | SI | RInImp-Rlperf | Antti Toskala, Nokia Networks | antti.toskala@nokia.com | TSG | Active | 1216 |  |  |
| 15 | 5.8 | FS on UTRA WideBand Distribution Systems | 790d | 2001-03-12 A | 2004-03-19 | 50% | 395d |  |  |  | 205d | start no earlier than 2001-03-12 | R4 | 6320h | 3160h | Rel-6 | SI | RInImp-WDS | Andrea Casini, Tekmar Sistemi | carlo.matarasso@andrew.com | TSG | Active | 1216 |  |  |
| 16 | 5.9 | FS on Improvement of inter-frequency and inter-system measurements for 1.28 Mcps TDD | 461d | 2001-12-14 A | 2003-09-19 A | 100% |  |  |  |  |  | start no earlier than 2001-12-14 | R1 | 3688h | 3688h | Rel-6 | SI | RInImp-IfIsMLCR | Li Xiao Qiang, SAMSUNG | xqli@samsung.co.kr | TSG | Active | 1216 |  | 10 |
| 17 | 5.10 | FS for the analysis of OFDM for UTRAN enhancement | 526d | 2002-06-10 A | 2004-06-14 | 40% | 315.6d |  |  |  | 144d | start no earlier than 2002-06-10 | R1 | 4208h | 1683.2h | Rel-6 | SI | RInImp-FSOFDM | Sarah Boumendil, Nortel | boumendi@nortelnetworks.com | TSG | Active | 1216 |  | 11 |
| 18 | 5.11 | FS on Uplink Enhancements for Dedicated Transport Channels | 326d | 2002-09-06 A | 2003-12-05 | 50% | 163d |  |  |  | 280d | start no earlier than 2002-09-06 | R1 | 2608h | 1304h | Rel-6 | SI | RInImp-FSUpDTrCh | Karri Ranta-aho, Nokia | Karri.Ranta-aho@nokia.com | TSG | Active | 1216 |  | 12 |
| 19 | 5.12 | FS on Analysis on Higher Chip Rates for UTRA TDD evolutions | 326d | 2002-09-06 A | 2003-12-05 | 50% | 163d |  |  |  | 280d | start no earlier than 2002-09-06 | R1 | 2608h | 1304h | Rel-6 | SI | RInImp-FSVHCRTDD | Tim Wilkinson, IPWireless | mbeale@ipwireless.com | TSG | Active | 1216 |  | 13 |
| 20 | 5.13 | FS on Low Output Powers for general purpose FDD BSs | 136d | 2003-06-13 A | 2004-03-24 | 50% | 68d |  |  |  | 202d | start no earlier than 2003-06-13 | R3 | 1088h | 544h | Rel-6 | SI | RInImp-FSLOP | Ana Burgos, Telefonica | burgos_a@tsm.es | TSG | Active | 1216 |  | 14 |
| 21 | 5.14 | FS on Uplink enhancements for UTRA TDD | 206d | 2003-06-06 A | 2004-03-19 | 5% | 195.7d |  |  |  | 205d | start no earlier than 2003-06-06 | R1 | 1648h | 82.4h | Rel-6 | SI | RInImp-FSUpEnhTDD | Marian Rudolf, Interdigital | Marian.Rudolf@InterDigital.com | TSG | Active | 1216 |  | 15 |
| 22 | 8.8 | FS on UE antenna efficiency test methods performance requirements (2) | 131d | 2002-03-08 A | 2002-09-06 A | 100% |  | 2002-03-08 | 2002-09-06 | 131d |  | finish no earlier than 2002-09-06 | R4 | 1048h | 1048h | Rel-6 |  | RInImp-UEAnTM2 | Alf Ahlström, Allgon |  | TSG |  |  |  |  |
| 23 | 8.5 | **Multiple Input Multiple Output antennas (MIMO)** | 480d? | 2003-03-03 A | 2004-12-31 | 13% | 417.35d? | 2003-03-14 | 2004-12-17 | 461d? | 0d |  | R1 | 13992h | 3433.6h | Rel-6 | 2468 | MIMO | Howard Huang, Lucent | hchuang@lucent.com | TSG |  |  |  |  |
| 24 | 6.1 | Multiple Input Multiple Output antennas - Physical layer | 266d? | 2003-03-14 A | 2004-03-19 | 30% | 186.2d? | 2003-03-14 | 2004-03-19 | 266d? | 205d | finish no earlier than 2004-03-19 | R1 | 2128h | 638.4h | Rel-6 |  | MIMO-Phys | Howard Huang, Lucent | hchuang@lucent.com | TSG |  |  |  |  |
| 25 | 6.2 | Multiple Input Multiple Output antennas - Layer 2,3 aspects | 266d? | 2003-03-14 | 2004-03-19 |  |  | 2003-09-12 | 2004-03-19 | 136d? | 205d | start no earlier than 2003-03-14 | R2 | 2128h |  | Rel-6 |  | MIMO-L23 | Howard Huang, Lucent | hchuang@lucent.com | TSG |  |  |  |  |
| 26 | 6.3 | Multiple Input Multiple Output antennas - Iub/Iur Protocol Aspects | 266d? | 2003-03-14 | 2004-03-19 |  |  | 2003-03-14 | 2003-09-19 | 136d? | 205d | finish no earlier than 2004-03-19 | R3 | 2128h |  | Rel-6 |  | MIMO-IurIub | Howard Huang, Lucent | hchuang@lucent.com | TSG |  |  |  |  |
| 27 | 6.4 | Multiple Input Multiple Output antennas - RF Radio Transmission/Reception, System Performance Requirements and Conformance Testing | 480d? | 2003-03-03 A | 2004-12-31 | 18% | 393d? | 2003-12-12 | 2004-12-17 | 266d? | 0d | start no earlier than 2003-03-01 | R4 | 3840h | 696h | Rel-6 |  | MIMO-RF | Man Hung Ng, Lucent | ngm@lucent.com | TSG |  |  |  |  |

Notes:
- 5: This is a generic feature without particular end date
- 6: This is a generic feature without particular end date
- 22: The RInImp-UEAnTM FS was re-opened at TSG RAN#15 upon request from WG4

| ID | WBS | Task | Duration | Start | Finish | Complete | Remaining | Baseline start | Baseline finish | Baseline duration | Total slack | Constraint | Resources | Work | Actual work | Text1 | Text6 | Text7 | Text2 | Text4 | Text5 | Text9 | Text3 | Text10 | Text11 | Text12 | Text8 |
| --- | --- | --- | --- | --- | --- | --- | --- | --- | --- | --- | --- | --- | --- | --- | --- | --- | --- | --- | --- | --- | --- | --- | --- | --- | --- | --- | --- |
| 28 | 9 | **RAN improvements** | 591d? | 2001-12-14 A | 2004-03-19 | 44% | 333d? | 2001-12-14 | 2004-03-19 | 591d? | 205d |  | RP | 26296h | 10323.2h | RANimp | Rel-6 | TSG |  |  |  |  |  |  |  |  |  |
| 29 | 9.2 | **RAB support enhancement** | 266d? | 2003-03-14 A | 2004-03-19 | 10% | 239.4d? | 2003-03-14 | 2004-03-19 | 266d? | 205d |  | R2 | 4256h | 425.6h | RANimp-RABSE | Rel-6 | TSG | BaAS | Juha Mikola, Nokia | juha.mikola@nokia.com | 624 |  |  |  |  |  |
| 30 | 7.1.1 | Iu enhancements for IMS support in RAN | 266d? | 2003-03-14 A | 2004-03-19 | 10% | 239.4d? | 2003-03-14 | 2004-03-19 | 266d? | 205d | finish no earlier than 2004-03-19 | R3 | 2128h | 212.8h | RANimp-RABSE-IuEnhIMS | Rel-6 | TSG |  | Phillipe Godin, Nortel | Philippe.Godin@nortelnetworks.com |  |  |  |  |  |  |
| 31 | 9.3 | Improvement of RRM across RNS and RNS/BSS | 445d | 2002-03-25 A | 2003-12-05 | 35% | 289.25d | 2002-03-25 | 2003-12-05 | 445d | 280d | finish no earlier than 2003-12-05 | R3 | 3560h | 1246h | RANimp-RRM1 | Rel-6 | TSG |  | Antti Toskala, Nokia | antti.toskala@nokia.com |  |  |  |  |  |  |
| 32 | 9.1 | Beamforming Enhancements | 521d | 2001-12-14 A | 2003-12-12 | 90% | 52.1d | 2001-12-14 | 2003-09-19 | 461d | 275d | finish no earlier than 2003-12-12 | R1 | 4168h | 3751.2h | RANimp-BFE | Rel-6 | TSG |  | Jussi Kähtävä, Nokia | jussi.kahtava@nokia.com |  |  |  |  |  |  |
| 33 | 7.4 | **Rel6 RRM optimization for Iur and Iub** | 126d | 2003-09-19 | 2004-03-12 |  |  | 2002-12-06 | 2003-09-19 | 206d? | 210d |  | R3 | 2016h |  | RANimp-RRMopt | Rel-6 | TSG | BaAS | Gert-Jan van Lieshout, Ericsson | Gert-Jan.van.Lieshout@eln.ericsson.se |  |  |  |  |  |  |
| 34 | 7.4.1 | Improved access to User Equipment (UE) measurement data for Controlling Radio Network Controller (CRNC) to support Time Division Duplex (TDD) Radio Resource Management (RRM) | 126d | 2003-09-19 | 2004-03-12 |  |  |  |  |  | 210d | start no earlier than 2003-09-19 | R3 | 1008h |  | RANimp-RRMopt-UEMsD | Rel-6 | TSG |  | Jim Miller, Interdigital | jim.miller@interdigital.com | WT | TS25.423 | 23012 | Active | 22 |  |
| 35 | 7.5 | Remote Control of Electrical Tilting Antennas | 261d? | 2003-03-14 A | 2004-03-12 | 15% | 221.85d? | 2003-03-14 | 2003-12-05 | 191d? | 210d | finish no earlier than 2004-03-12 | R3 | 2088h | 313.2h | RANimp-TiltAnt | Rel-6 | TSG |  | Andreas Hauser, Vodafone | Andreas.Hauser@vodafone.com |  |  |  |  |  |  |
| 36 | 7.6 | Network Assisted Cell Change (NACC) from UTRAN to GERAN - network-side aspects | 136d? | 2003-06-13 A | 2003-12-19 | 30% | 95.2d? | 2003-06-13 | 2003-12-19 | 136d? | 270d | finish no earlier than 2003-12-19 | R3 | 1088h | 326.4h | RANimp-NACC | Rel-6 | TSG |  | Brendan McWilliams, Vodafone | Brendan.McWilliams@gb.vodafone.co.uk |  |  |  |  |  |  |
| 37 | 7.7 | FS of the improved access to UE measurement data for CRNC to support TDD RRM | 206d? | 2002-12-06 A | 2003-09-19 A | 100% |  | 2002-12-06 | 2003-09-19 | 206d? |  | finish no earlier than 2003-09-30 | R3 | 1648h | 1648h | RANimp-RRMopt-FSUEMsD | Rel-6 | TSG |  | Jim Miller, Interdigital | jim.miller@interdigital.com |  |  |  |  |  |  |
| 38 | 9.4 | FS on the evolution of the UTRAN architecture | 343d | 2002-09-09 A | 2003-12-31 | 20% | 274.4d | 2002-09-09 | 2003-12-19 | 335d | 262d | finish no earlier than 2003-12-31 | R3 | 2744h | 548.8h | RANimp-FSEvo | Rel-6 | TSG |  | Antti Toskala, Nokia | antti.toskala@nokia.com |  |  |  |  |  |  |
| 39 | 8 | **PS domain and IMS impacts for supporting IMS Emergency calls** | 995d? | 2000-08-14 A | 2004-06-04 | 31% | 689.11d? | 2000-08-14 | 2003-12-12 | 870d? | 150d |  | S2 | 38056h | 10213.5h | EMC1 | Rel-6 | TSG |  | Rainer Liebhart |  |  |  |  |  |  |  |
| 40 | 10.1.1 | Service Requirements for IP-based emergency calls | 725d | 2000-09-18 A | 2003-06-27 | 90% | 72.5d | 2000-09-18 | 2003-06-27 | 725d | 395d | finish no earlier than 2003-06-27 | S1 | 5800h | 5220h |  | Rel-6 |  | CCaR |  |  | 1314 | 22.976 |  |  |  |  |
| 41 | 8.2 | Stage 2 | 308d? | 2003-02-26 A | 2004-04-30 | 36% | 197.12d? | 2003-02-26 | 2003-09-18 | 147d? | 175d | finish no earlier than 2004-04-30 | S2 | 2464h | 887.04h |  | Rel-6 | TSG |  | Miikka Poikselka, Nokia |  |  |  |  |  |  |  |
| 42 | 10.1 | **Emergency Call Enhancements for IP& PS Based Calls – stage 3** | 995d | 2000-08-14 A | 2004-06-04 | 8% | 917.28d | 2000-08-14 | 2003-12-12 | 870d | 150d |  | N1 | 22032h | 1720.85h |  | Rel-6 |  | CCaR | Mr Atle Monrad, Ericsson | Atle.Monrad@eto.ericsson.se | 1653 |  |  |  |  |  |
| 43 | 10.1.2 | SIP emergency calls and packet emergency calls signalling flows | 949d | 2000-10-17 A | 2004-06-04 | 16% | 797.16d | 2000-10-17 | 2003-12-12 | 824d | 150d | finish no earlier than 2004-06-04 | N1 | 7592h | 1214.72h |  | Rel-6 |  | CCaR | Mr Atle Monrad, Ericsson | Atle.Monrad@eto.ericsson.se | 1315 | TS 24.228 |  |  |  |  |
| 44 | 10.1.5 | Stage 3 for emergency calls and packet emergency calls in general | 995d | 2000-08-14 | 2004-06-04 |  |  | 2000-08-14 | 2003-12-12 | 870d | 150d | finish no earlier than 2004-06-04 | N1 | 7960h |  |  | Rel-6 |  | CCaR | Mr Atle Monrad, Ericsson | Atle.Monrad@eto.ericsson.se | 1646 | TS 24.229 |  |  |  |  |
| 45 | 12 | **Location Services enhancements 2** | 994d? | 2000-05-30 A | 2004-03-19 | 55% | 446.01d? | 2000-08-28 | 2004-03-19 | 930d? | 205d |  | S2 | 70864h | 38531.1h | LCS2 | Rel-6 | TSG |  |  |  |  |  |  |  |  | Sang-Ui |
| 46 | 12.1 | **Improvement on Le interface** | 397d? | 2002-06-17 A | 2003-12-23 | 60% | 157.55d? | 2002-06-17 | 2003-12-23 | 397d? | 268d |  | S2 | 6776h | 4086.98h |  | Rel-6 | TSG |  |  |  |  |  |  |  |  |  |
| 47 | 9.1.1 | Stage 2 | 331d? | 2002-06-17 A | 2003-09-22 | 82% | 59.58d? | 2002-06-17 | 2003-09-22 | 331d? | 334d | start no earlier than 2002-06-17 | S2 | 2648h | 2171.36h |  | Rel-6 |  |  |  |  |  |  |  |  |  |  |
| 48 | 9.1.2 | Stage 3 in OMA - it impacts Mobile Location Protocol (MLP) | 119d? | 2003-07-10 | 2003-12-23 |  |  | 2003-07-10 | 2003-12-23 | 119d? | 268d | finish no earlier than 2003-12-23 | OMA | 952h |  |  | Rel-6 |  |  |  |  |  |  |  |  |  |  |
| 49 | 12.2 | **Enhanced support for anonymity and user privacy** | 382d? | 2002-07-08 A | 2003-12-23 | 68% | 121.55d? | 2002-07-08 | 2003-12-23 | 382d? | 268d |  | S2 | 6048h | 4072.03h |  | Rel-6 | TSG |  |  |  |  |  |  |  |  |  |
| 50 | 9.2.1 | Stage 2 | 255d? | 2002-07-08 A | 2003-06-27 A | 100% |  | 2002-07-08 | 2003-06-27 | 255d? |  | finish no earlier than 2003-06-27 | S2 | 2040h | 2040h |  | Rel-6 |  |  |  |  |  |  |  |  |  |  |
| 51 | 9.2.2 | Stage 3 in OMA (it impacts MLP and RLP) | 119d? | 2003-07-10 | 2003-12-23 |  |  | 2003-07-10 | 2003-12-23 | 119d? | 268d | finish no earlier than 2003-12-23 | OMA | 952h |  |  | Rel-6 |  |  |  |  |  |  |  |  |  |  |

Notes:
- 28: This is a generic feature without particular end date
- 29: This is a building block without particular end date
- 34: Approved at TSG RAN#21 as RP-030539

| ID | WBS | Task | Duration | Start | Finish | Complete | Remaining | Baseline start | Baseline finish | Baseline duration | Total slack | Constraint | Resources | Work | Actual work | Text6 | Text7 | Text1 | Text4 | Text5 | Text9 | Text8 |
| --- | --- | --- | --- | --- | --- | --- | --- | --- | --- | --- | --- | --- | --- | --- | --- | --- | --- | --- | --- | --- | --- | --- |
| 52 | 12.3 | **Enhanced inter-GMLC interface** | 320d? | 2002-06-24 A | 2003-09-12 | 76% | 75.82d? | 2002-06-24 | 2003-09-12 | 320d? | 340d |  | S2 | 7240h | 5524.68h | Rel-6 | TSG |  |  |  |  |  |
| 53 | 9.3.1 | Stage 2 | 315d? | 2002-06-24 A | 2003-09-05 | 86% | 44.1d? | 2002-06-24 | 2003-09-05 | 315d? | 345d | finish no earlier than 2003-09-05 | S2 | 2520h | 2167.2h | Rel-6 |  |  |  |  |  |  |
| 54 | 9.3.2 | Stage 3 in OMA (definition of RLP and PCP) | 270d? | 2002-09-02 A | 2003-09-12 | 65% | 94.5d? | 2002-09-02 | 2003-09-12 | 270d? | 340d | finish no earlier than 2003-09-12 | OMA | 2160h | 1404h | Rel-6 |  |  |  |  |  |  |
| 55 | 12.4 | **Location Services support for IMS public identities** | 340d? | 2002-09-02 A | 2003-12-19 | 39% | 208.75d? | 2002-09-02 | 2003-12-19 | 340d? | 270d |  | S2 | 6160h | 2377.98h | Rel-6 | TSG |  |  |  |  |  |
| 56 | 9.4.1 | Stage 2 | 215d? | 2003-02-24 A | 2003-12-19 | 19% | 174.15d? | 2003-02-24 | 2003-12-19 | 215d? | 270d | finish no earlier than 2003-12-19 | S2 | 1720h | 326.8h | Rel-6 |  |  |  |  |  |  |
| 57 | 9.4.2 | Stage 3 in OMA (impacts MLP, RLP and PCP) | 340d? | 2002-09-02 A | 2003-12-19 | 51% | 166.6d? | 2002-09-02 | 2003-12-19 | 340d? | 270d | finish no earlier than 2003-12-19 | OMA | 2720h | 1387.2h | Rel-6 |  |  |  |  |  |  |
| 58 | 12.5 | **New area event for location service triggering reports** | 406d? | 2002-06-03 A | 2003-12-22 | 55% | 184.4d? | 2002-06-03 | 2003-12-22 | 406d? | 269d |  | S2 | 7352h | 4472.03h | Rel-6 | TSG |  |  |  |  |  |
| 59 | 9.5.1 | Stage 2 | 280d? | 2002-06-03 A | 2003-06-27 A | 100% |  | 2002-06-03 | 2003-06-27 | 280d? |  | finish no earlier than 2003-06-27 | S2 | 2240h | 2240h | Rel-6 |  |  |  |  |  |  |
| 60 | 9.5.2 | Stage 3 for UE-CN signalling | 118d? | 2003-07-10 | 2003-12-22 |  |  | 2003-07-10 | 2003-12-22 | 118d? | 269d | finish no earlier than 2003-12-22 | N4 | 944h |  | Rel-6 |  |  |  |  |  |  |
| 61 | 9.5.3 | Stage 3 in OMA (impacts MLP, RLP and PCP) | 115d? | 2003-07-14 | 2003-12-19 |  |  | 2003-07-14 | 2003-12-19 | 115d? | 270d | finish no earlier than 2003-12-19 | OMA | 920h |  | Rel-6 |  |  |  |  |  |  |
| 62 | 12.6 | **FS on applicability of GALILEO for LCS** | 445d? | 2002-07-08 A | 2004-03-19 | 51% | 218.69d? | 2002-07-08 | 2004-03-19 | 445d? | 205d |  | S2 | 7760h | 3136h | Rel-6 |  |  |  |  |  |  |
| 63 | 9.6.1 | TR on Stage 2 | 445d? | 2002-07-08 A | 2004-03-19 | 60% | 178d? | 2002-07-08 | 2004-03-19 | 445d? | 205d | finish no earlier than 2004-03-19 | S2 | 3560h | 2136h | Rel-6 |  |  |  |  |  |  |
| 64 | 9.6.2 | GERAN review of the TR | 80d? | 2003-08-25 | 2003-12-12 |  |  | 2003-08-25 | 2003-12-12 | 80d? | 275d | finish no earlier than 2003-12-12 | GP | 640h |  | Rel-6 |  |  |  |  |  |  |
| 65 | 12.7 | **UE positionning** | 994d? | 2000-05-30 A | 2004-03-19 | 51% | 484.72d? | 2000-08-28 | 2004-03-19 | 930d? | 205d |  | RP | 23688h | 11641.8h | Rel-6 | TSG | LCS2-UEpos |  |  |  |  |
| 66 | 12.7.1 | UE positioning enhancements - other methods | 805d | 2000-05-30 | 2003-06-30 |  |  | 2000-08-28 | 2003-09-26 | 805d | 394d | finish no earlier than 2003-06-30 | R2 | 6440h |  | Rel-6 | TSG | LCS2-UEpos-enh | Meik Kottkamp, Siemens | Meik.Kottkamp@siemens.com | 2457 |  |
| 67 | 12.8 | Open SMLC-SRNC Interface within the UTRAN to support UTRAN Rel4 positioning methods | 700d? | 2001-01-15 A | 2003-09-19 A | 100% |  | 2001-01-15 | 2003-09-19 | 700d? |  | finish no earlier than 2003-09-19 | R2 | 5600h | 5600h | Rel-6 | TSG | LCS-Rel4Pos | Meik Kottkamp, Siemens | Meik.Kottkamp@siemens.com | 2475 |  |
| 68 | 9.7.3 | A-GPS minimum performance specification | 206d? | 2003-06-06 A | 2004-03-19 | 10% | 185.4d? | 2003-06-06 | 2004-03-19 | 206d? | 205d | finish no earlier than 2004-03-19 | R4 | 1648h | 164.8h | Rel-6 | TSG | LCS-UEPos-AGPSPerf | Donglin Shen, AT&T Wireless Services | donglin.shen@attws.com |  |  |
| 69 | 12.7.2 | FS on Enhancements to OTDOA Positioning using advanced blanking methods | 320d | 2002-07-01 A | 2003-09-19 A | 100% |  | 2002-07-01 | 2003-09-19 | 320d |  | finish no earlier than 2003-09-19 | R2 | 2560h | 2560h | Rel-6 | TSG | LCS2-UEpos-FSBlank | David Bartlett, Cambridge Positioning Systems | david.bartlett@cursor-system.com |  |  |
| 70 | 10 | **Uplink TDOA location determination for GSM/GPRS** | 521d | 2002-11-15 A | 2004-11-12 | 28% | 374.84d | 2002-11-15 | 2003-11-21 | 266d | 35d |  | GP | 11344h | 2213.79h | Rel-6 | TSG | UTDOA | Gross/Robinson, TruePosition, Inc. |  |  | Paolo |
| 71 | 10.1 | Addition of U-TDOA in the CS domain | 376d | 2002-11-15 A | 2004-04-23 | 60% | 150.4d | 2002-11-15 | 2003-06-27 | 161d | 180d | finish no earlier than 2004-04-23 | GP | 3008h | 1804.8h | Rel-6 |  | UTDOA-CS |  |  |  |  |
| 72 | 10.2 | Addition of U-TDOA in the PS domain | 521d | 2002-11-15 A | 2004-11-12 | 5% | 494.95d | 2002-11-15 | 2003-11-21 | 266d | 35d | finish no earlier than 2004-11-12 | GP | 4168h | 208.4h | Rel-6 |  | UTDOA-PS |  |  |  |  |
| 73 | 14 | **Security enhancements** | 712d | 2001-01-03 A | 2003-09-25 | 23% | 545d | 2001-01-03 | 2003-03-14 | 573d | 331d |  | S3 | 19760h | 5344h | Rel-6 | TSG | SEC1 | Peter Howard, Vodafone | Peter.Howard@vodafone.com |  | Maurice |
| 74 | 14.1 | **Enhanced HE control of security (including positive authentication reporting)** | 712d | 2001-01-03 A | 2003-09-25 | 23% | 545d | 2001-01-03 | 2003-03-14 | 573d | 331d |  | S3 | 14064h | 4008h | Rel-6 |  |  | Peter Howard, Vodafone | Peter.Howard@vodafone.com | 2026 |  |
| 75 | 14.1.1 | Stage 2 | 378d | 2001-01-03 | 2002-06-14 |  |  | 2001-01-03 | 2002-06-14 | 378d | 665d | finish no earlier than 2002-06-14 | S3 | 3024h |  | Rel-6 |  |  |  |  | 2027 |  |

Notes:
- 65: This is a building block without particular end date
- 70: Ongoing
- 72: Not started
- 73: Added BB UE authentication and rapporteur added.
- 74: Added by P-000575 without any dates. 18/10/00: Change of WI title, added hyperlink rapporteur new end date 03/01. New end date and correct Release to be decided S3#18
- 75: New end date and correct Release to be decided S3#18

| ID | WBS | Task | Duration | Start | Finish | Complete | Remaining | Baseline start | Baseline finish | Baseline duration | Total slack | Constraint | Resources | Work | Actual work | Text1 | Text2 | Text4 | Text5 | Text6 | Text7 | Text3 | Text8 |
| --- | --- | --- | --- | --- | --- | --- | --- | --- | --- | --- | --- | --- | --- | --- | --- | --- | --- | --- | --- | --- | --- | --- | --- |
| 76 | 14.1.3 | **Network domain security** | 334d | 2002-06-17 A | 2003-09-25 | 50% | 167d | 2002-06-17 | 2003-03-14 | 195d | 331d |  | S3 | 5344h | 2672h | SEC1-NDS | Sec | Geir M. Køien, Telenor | Geir-myrdahl.koien@telenor.com | Rel-6 | TSG |  |  |
| 77 | 14.1.3.1 | IP network layer security (NDS/IP) | 334d | 2002-06-17 A | 2003-09-25 | 50% | 167d | 2002-06-17 | 2003-03-14 | 195d | 331d | finish no earlier than 2003-09-25 | S3 | 2672h | 1336h | SEC1-NDS-IP |  |  |  | Rel-6 | WG | TS 33.210 |  |
| 78 | 16 | **IMS Phase 2** | 1000d? | 2000-08-28 A | 2004-06-25 | 45% | 547.45d? | 2000-08-28 | 2003-12-18 | 864d? | 135d |  | S1 | 107449h | 46323.1h | IMS2 |  |  |  | Rel-6 | TSG |  | Sang-Ui |
| 79 | 16.1 | Stage 2 of IMS Phase 2 | 275d | 2002-09-02 A | 2003-09-19 | 80% | 55d | 2002-09-02 | 2003-09-19 | 275d | 335d | finish no earlier than 2003-09-19 | S2 | 2200h | 1760h |  |  |  |  | Rel-6 |  |  |  |
| 80 | 12.2 | Enhancements to the Cx and Sh interfaces | 136d? | 2003-06-06 A | 2003-12-12 | 10% | 122.4d? | 2003-06-06 | 2003-12-12 | 136d? | 275d | finish no earlier than 2003-12-12 | N4 | 1088h | 108.8h | IMS2-CCR |  |  |  | Rel-6 | WG |  |  |
| 81 | 16.12 | **IMS Group Management** | 582d? | 2002-03-14 A | 2004-06-04 | 29% | 412.79d? | 2002-03-14 | 2003-12-12 | 457d? | 150d |  | S1 | 10552h | 3067.81h | IMSGM |  | Juha Kalliokulju (Nokia) | juha.kalliokulju@nokia.com | Rel-6 | TSG |  |  |
| 82 | 16.12.1 | Stage 1 - TS on IMS group management | 193d | 2002-03-14 A | 2002-12-09 | 75% | 48.25d | 2002-03-14 | 2002-12-09 | 193d | 539d | finish no earlier than 2002-12-09 | S1 | 1544h | 1158h |  |  | Juha Kalliokulju (Nokia) | juha.kalliokulju@nokia.com | Rel-6 | TSG |  |  |
| 83 | 12.3.2 | Stage 2 | 158d? | 2003-05-26 A | 2003-12-31 | 44% | 88.48d? | 2003-05-26 | 2003-09-23 | 87d? | 262d | finish no earlier than 2003-12-31 | S2 | 1264h | 556.16h |  |  |  |  | Rel-6 |  |  |  |
| 84 | 12.3.3 | Stage 3 for IMS Group management (e.g. chat) | 386d? | 2002-12-13 | 2004-06-04 |  |  | 2002-12-13 | 2003-12-12 | 261d? | 150d | finish no earlier than 2004-06-04 | N1 | 3088h |  |  |  | Keith Drage, Lucent | drage@lucent.com |  |  |  |  |
| 85 | 12.4 | **IMS Conferencing** | 415d? | 2002-11-04 A | 2004-06-04 | 56% | 182.69d? | 2002-11-04 | 2003-12-12 | 290d? | 150d |  | N1 | 8304h | 4648.37h |  |  |  |  | Rel-6 |  |  |  |
| 86 | 12.4.1 | Stage 2 | 237d? | 2002-11-04 A | 2003-09-30 | 82% | 42.66d? | 2002-11-04 | 2003-09-26 | 235d? | 328d | finish no earlier than 2003-09-30 | S2 | 1896h | 1554.72h |  |  |  |  | Rel-6 |  |  |  |
| 87 | 12.4.2 | Stage 3 | 386d? | 2002-12-13 A | 2004-06-04 | 40% | 231.6d? | 2002-12-13 | 2003-12-12 | 261d? | 150d | finish no earlier than 2004-06-04 | N1 | 3088h | 1235.2h |  |  | Keith Drage, Lucent | drage@lucent.com |  |  |  |  |
| 88 | 16.11 | **IMS Messaging** | 582d? | 2002-03-14 A | 2004-06-04 | 58% | 244.7d? | 2002-03-14 | 2003-12-12 | 457d? | 150d |  | S1 | 15560h | 9376.36h | IMSM |  | Juha Kalliokulju (Nokia) | juha.kalliokulju@nokia.com | Rel-6 | TSG |  |  |
| 89 | 16.11.1 | TR on support of messaging in the IMS | 193d | 2002-03-14 A | 2002-12-09 A | 100% |  | 2002-03-14 | 2002-12-09 | 193d |  | finish no earlier than 2002-12-09 | S1 | 1544h | 1544h | IMSM-TR |  | Juha Kalliokulju (Nokia) | juha.kalliokulju@nokia.com | Rel-6 | TSG |  |  |
| 90 | 12.5.2 | Stage 1 22.340 | 23d? | 2002-11-11 A | 2002-12-11 A | 100% |  | 2002-11-11 | 2002-12-11 | 23d? |  | finish no earlier than 2002-12-11 | S1 | 184h | 184h | IMSM-TS |  | Juha Kalliokulju (Nokia) | juha.kalliokulju@nokia.com | Rel-6 | TSG | 22.340 |  |
| 91 | 16.11.2 | **CRs to existing 22-series specifications** | 263d? | 2002-03-14 A | 2003-03-17 | 75% | 65.75d? | 2002-03-14 | 2003-03-17 | 263d? | 469d |  | S1 | 4208h | 3156h | IMSM-CR |  | Juha Kalliokulju (Nokia) | juha.kalliokulju@nokia.com | Rel-6 | TSG |  |  |
| 92 | 12.5.3.1 | CRs to 22.140 & 22.228 | 263d? | 2002-03-14 A | 2003-03-17 | 75% | 65.75d? | 2002-03-14 | 2003-03-17 | 263d? | 469d | finish no earlier than 2003-03-17 | S1 | 2104h | 1578h | IMSM-CR |  | Juha Kalliokulju (Nokia) | juha.kalliokulju@nokia.com | Rel-6 | TSG | 22.140,22.228 |  |
| 93 | 16.11.3 | Stage 2 | 235d | 2002-11-04 A | 2003-09-26 | 79% | 49.35d | 2002-11-04 | 2003-09-26 | 235d | 330d | finish no earlier than 2003-09-26 | S2 | 1880h | 1485.2h |  |  |  |  | Rel-6 |  |  |  |
| 94 | 12.5.5 | Stage 3 for IMS Messaging | 386d? | 2002-12-13 A | 2004-06-04 | 10% | 347.4d? | 2002-12-13 | 2003-12-12 | 261d? | 150d | finish no earlier than 2004-06-04 | N1 | 3088h | 308.8h |  |  | Keith Drage, Lucent | drage@lucent.com |  |  |  |  |
| 95 | 16.7 | **IMS Local services** | 895d? | 2001-01-01 A | 2004-06-04 | 46% | 485.89d? | 2001-01-01 | 2003-12-12 | 770d? | 150d |  | S2 | 12848h | 5192.02h |  |  |  |  | Rel-6 |  | 23.228 |  |
| 96 | 16.7.1 | Stage 2 | 325d | 2001-01-01 A | 2002-03-29 A | 100% |  | 2001-01-01 | 2002-03-29 | 325d |  | start no earlier than 2001-01-01 | S2 | 2600h | 2600h |  |  |  |  | Rel-6 |  |  |  |
| 97 | 12.6.2 | Stage 3 for IMS Local services | 386d? | 2002-12-13 | 2004-06-04 |  |  | 2002-12-13 | 2003-12-12 | 261d? | 150d | finish no earlier than 2004-06-04 | N1 | 3088h |  |  |  | Keith Drage, Lucent | drage@lucent.com |  |  |  |  |
| 98 | 12.7 | **Additional SIP Capabilities support not covered by Rel-5** | 285d? | 2002-11-11 A | 2003-12-12 | 51% | 139.69d? | 2002-11-11 | 2003-12-12 | 285d? | 275d |  | N1 | 5688h | 2900.08h |  |  |  |  | Rel-6 |  |  |  |
| 99 | 12.7.1 | Stage 2 for add SIP cap (e.g. forking) | 165d? | 2002-11-11 A | 2003-06-27 A | 100% |  | 2002-11-11 | 2003-06-27 | 165d? |  | start no earlier than 2002-11-11 | S2 | 1320h | 1320h |  |  |  |  | Rel-6 |  |  |  |
| 100 | 12.7.2 | Stage 3 for Additional SIP Capabilities | 261d? | 2002-12-13 A | 2003-12-12 | 20% | 208.8d? | 2002-12-13 | 2003-12-12 | 261d? | 275d | finish no earlier than 2003-12-12 | N1 | 2088h | 417.6h |  |  | Keith Drage, Lucent | drage@lucent.com |  |  |  |  |
| 101 | 12.8 | Review additional SIP Capabilities against IMS | 326d? | 2002-12-13 | 2004-03-12 |  |  | 2002-12-13 | 2003-12-12 | 261d? | 210d | finish no earlier than 2004-03-12 | N1 | 2608h |  |  |  | Keith Drage, Lucent | drage@lucent.com |  |  |  |  |

Notes:
- 76: WID approved for Rel-6 at SA#17
- 77: Should be complete after SA3#27
- 78: Not yet available: verbally approved at SA15, actual WID to be provided at SA16 by Lucent
- 80: 29./05/2003 CN4: New WID presented for approval at CN#20

| ID | WBS | Task | Duration | Start | Finish | Complete | Remaining | Baseline start | Baseline finish | Baseline duration | Total slack | Constraint | Resources | Work | Actual work | Text1 | Text2 | Text3 | Text4 | Text5 | Text6 | Text7 | Text9 | Text8 |
| --- | --- | --- | --- | --- | --- | --- | --- | --- | --- | --- | --- | --- | --- | --- | --- | --- | --- | --- | --- | --- | --- | --- | --- | --- |
| 102 | 16.5 | **Interworking between IMS and IP networks** | 860d | 2000-08-28 A | 2003-12-12 | 57% | 372.13d | 2000-08-28 | 2003-12-12 | 860d | 275d |  | N3 | 19600h | 9336h | IMS-CCR-IWIP | BaAS | 23.821, 29.061, 29.162 | Nigel Holland, BT | nigel.holland@bt.com | Rel-6 | TSG | 2048 |  |
| 103 | 16.5.1 | Interworking for 3GPP_SIP and IETF_SIP | 730d | 2000-08-28 A | 2003-06-13 A | 100% |  | 2000-08-28 | 2003-12-12 | 860d |  | finish no earlier than 2003-06-13 | N3 | 5840h | 5840h |  |  | New TR 29.962 | Thomas Belling, Siemens |  | Rel-6 |  |  |  |
| 104 | 16.5.2 | Interworking for IPv6 to IPv4 | 860d | 2000-08-28 A | 2003-12-12 | 20% | 688d | 2000-08-28 | 2003-12-12 | 860d | 275d | finish no earlier than 2003-12-12 | N3 | 6880h | 1376h |  |  | 29.163 |  |  | Rel-6 |  |  |  |
| 105 | 16.8 | **Mm interface (CSCF to external IP multimedia network) -- NOT CN3** | 718d | 2001-03-14 A | 2003-12-12 | 38% | 445.16d | 2001-03-14 | 2003-12-12 | 718d | 275d |  | N1 | 9305.28h | 2182.72h |  |  |  |  |  | Rel-6 |  |  |  |
| 106 | 16.8.1 | CN1 part | 718d | 2001-03-14 A | 2003-12-12 | 38% | 445.16d | 2001-03-14 | 2003-12-12 | 718d | 275d | finish no earlier than 2003-12-12 | N1 | 5744h | 2182.72h |  |  |  |  |  | Rel-6 |  |  |  |
| 107 | 16.6.1 | Interworking between IMS and CS networks | 800d? | 2000-08-28 A | 2003-09-19 | 79% | 168d? | 2000-08-28 | 2003-09-05 | 790d? | 335d | finish no earlier than 2003-09-19 | N3 | 6400h | 5056h | IMS-CCR-IWCS | CCaR | 29.163, 29.061, 24.228, and new CN4 specification | Brendan Mc Williams, Vodafone | brendan.mcwilliams@vf.vodafone.co.uk | Rel-6 | TSG |  |  |
| 108 | 16.10 | Mn interface (IM-MGW to MGCF) enhancements (CN3 Part) | 134d | 2002-09-02 | 2003-12-12 |  |  | 2002-09-02 | 2003-12-12 | 335d | 275d | finish no earlier than 2003-12-12 | N3 | 1072h |  | IMS-CCR-Mn |  |  |  |  | Rel-6 |  |  |  |
| 109 | 12.13 | Mp (MRFC - MRFP) interface (CN3 Part) | 279d | 2002-10-07 | 2003-12-12 |  |  | 2002-10-07 | 2003-12-12 | 310d? | 275d | start no earlier than 2002-10-07 | N3 | 2232h |  | IMS-CCR-Mp |  |  |  |  | Rel-6 |  |  |  |
| 110 | 12.14 | Study of subscriber and operators relationship in IMS and related ISIM requirements for Rel 6” | 20d? | 2002-11-15 A | 2002-12-12 A | 100% |  | 2002-11-15 | 2002-12-12 | 20d? |  | finish no earlier than 2002-12-12 | S1 | 160h | 160h |  |  |  | Juha Kalliokulju (Nokia) | juha.kalliokulju@nokia.com | Rel-6 |  |  |  |
| 111 | 12.15 | Lawful Interception in the 3GPP Rel-6 architecture | 269d? | 2002-12-09 A | 2003-12-18 | 10% | 242.1d? | 2002-12-09 | 2003-12-18 | 269d? | 271d | finish no earlier than 2003-12-18 | S3 | 2152h | 215.2h | SEC1-LI |  | 33.106, 33.107, 33.108 | Berthold Wilhelm | Berthold.Wilhelm@REGTP.DE | Rel-6 | TSG |  |  |
| 112 | 12.16 | IMS Subscription and access scenarios | 130d? | 2002-12-16 A | 2003-06-13 | 58% | 55d? | 2002-12-16 | 2003-06-13 | 130d? | 405d | start no earlier than 2002-12-16 | S1 | 1040h | 600h |  |  | 22.800 |  |  | Rel-6 |  |  |  |
| 113 | 12.17 | 3GPP Enablers for services like Push to Talk over Cellular (PoC) | 145d? | 2003-09-08 | 2004-03-26 |  |  |  |  |  | 200d | finish no earlier than 2004-03-26 | S2 | 1160h |  |  |  | 23.9xx | Shabnam Sultana, Ericsson |  | Rel-6 |  |  |  |
| 114 | 12.18 | FS on Interworking aspects and migration scenarios for IPv4 based IMS Implementations | 210d? | 2003-09-08 | 2004-06-25 |  |  |  |  |  | 135d | finish no earlier than 2004-06-25 | S2 | 1680h |  |  |  |  | Alexander Milinski, Siemens |  | Rel-6 |  |  |  |
| 115 | 16.3 | **Interoperability and Commonality between IMS using different "IP-connectivity Networks"** | 325d? | 2002-09-16 A | 2003-12-12 | 58% | 138d? | 2002-09-16 | 2003-12-12 | 325d | 275d |  | S2 | 9120h | 3843.6h | IMSCOOP |  |  |  |  | Rel-6 | TSG |  | Sang-Ui |
| 116 | 16.3.1 | Stage 2 for Interoperability | 265d | 2002-09-16 A | 2003-09-19 | 79% | 55.65d | 2002-09-16 | 2003-09-19 | 265d | 335d | finish no earlier than 2003-09-19 | S2 | 2120h | 1674.8h |  |  |  | Balazs Beternyi, Nokia |  | Rel-6 |  |  |  |
| 117 | 13.2 | Stage 2 for commonality | 265d? | 2002-09-16 A | 2003-09-19 A | 100% |  | 2002-09-16 | 2003-09-19 | 265d? |  | start no earlier than 2002-09-16 | S2 | 2120h | 2120h |  |  |  | Balazs Beternyi, Nokia |  | Rel-6 |  |  |  |
| 118 | 16.3.2 | Stage 3 | 305d | 2002-10-14 A | 2003-12-12 | 2% | 298.9d | 2002-10-14 | 2003-12-12 | 305d | 275d | finish no earlier than 2003-12-12 | N1 | 2440h | 48.8h |  |  |  | Keith Drage, Lucent | drage@lucent.com | Rel-6 |  |  |  |
| 119 | 17 | **Support of Push Services** | 778d | 2001-01-03 A | 2003-12-26 | 85% | 113.27d | 2001-01-03 | 2003-12-26 | 778d | 265d |  | S1 | 12094.6h | 5816.8h | PUSH | CCaR |  | Yoshinori Kitada, NTT Comware |  | Rel-6 | TSG | 1365 | Sang-Ui |
| 120 | 17.1 | Stage 1 | 378d | 2001-01-03 A | 2002-06-14 A | 100% |  | 2001-01-03 | 2002-06-14 | 378d |  | finish no earlier than 2002-06-14 | S1 | 3024h | 3024h |  |  |  |  |  | Rel-6 |  |  |  |
| 121 | 17.2 | TR on feasibility study | 178d | 2001-01-03 A | 2001-09-07 A | 100% |  | 2001-01-03 | 2001-09-07 | 178d |  | finish no earlier than 2001-09-07 | S2 | 1424h | 1424h |  |  |  |  |  | Rel-6 |  |  |  |
| 122 | 17.3 | TR 23.976 on Push Architecture | 295d | 2002-11-11 A | 2003-12-26 | 58% | 123.9d | 2002-11-11 | 2003-12-26 | 295d | 265d | finish no earlier than 2003-12-26 | S2 | 2360h | 1368.8h |  |  |  | Nick Alfano, RIM |  | Rel-6 |  |  |  |
| 123 | 18 | **Multimedia Messaging (MMS) enhancements** | 410d? | 2002-08-15 A | 2004-03-10 | 28% | 295.27d? | 2002-08-15 | 2004-03-10 | 410d? | 212d |  | T2 | 17224h | 5895.41h | MMS6 | Mes |  | Josef Laumen, Siemens | Josef.Laumen@SAL.SIEMENS.DE | Rel-6 | TSG |  | Friedhelm |
| 124 | 18.1 | **Definition of service requirements** | 286d? | 2002-11-15 A | 2003-12-20 | 75% | 71.5d? | 2002-11-15 | 2003-12-20 | 286d? | 270d |  | S1 | 4576h | 3432h | MMS6-SR |  | 22.140 |  |  | Rel-6 |  |  |  |
| 125 | 15.1.1 | Definition of service requirements charging | 286d? | 2002-11-15 A | 2003-12-20 | 75% | 71.5d? | 2002-11-15 | 2003-12-20 | 286d? | 270d | finish no earlier than 2003-12-20 | S1 | 2288h | 1716h |  |  | 22.140 | Josef Laumen, Siemens | Josef.Laumen@SAL.SIEMENS.DE | Rel-6 |  |  |  |
| 126 | 18.2 | Technical realization | 410d | 2002-08-15 A | 2004-03-10 | 30% | 287d | 2002-08-15 | 2003-12-10 | 345d | 212d | finish no earlier than 2004-03-10 | T2 | 3280h | 984h |  |  | 23.140 | Josef Laumen, Siemens | Josef.Laumen@SAL.SIEMENS.DE | Rel-6 |  |  |  |
| 127 | 18.3 | OMA dependencies | 410d | 2002-08-15 | 2004-03-10 |  |  | 2002-08-15 | 2004-03-10 | 410d | 212d | finish no earlier than 2004-03-10 | T2 | 3280h |  |  |  |  |  |  | Rel-6 |  |  |  |
| 128 | 18.4 | MMS formats and codecs | 351d | 2002-08-15 A | 2003-12-18 | 20% | 280.8d | 2002-08-15 | 2003-12-18 | 351d | 271d | finish no earlier than 2003-12-18 | S4 | 2808h | 561.6h |  |  | 26.140 |  |  | Rel-6 |  |  | Paolo |

Notes:
- 102: [DAB 14.02.02] - end date pushed back to March 2003
- 103: [DAB - 20.08.03] - CN Part of TR Complete @ CN#20
- 105: [DAB - 23.05.03] - IS NOT THE RESPO OF CN3
- 107: [DAB - 23.05.03] - Remove ITU dependancies
- 108: Wed 15/10/03
- 109: Wed 15/10/03
- 119: AS: Changed from FS to actual support of Push
- 121: Stage 2 on hold, waiting for requirements.

| ID | WBS | Task | Duration | Start | Finish | Complete | Remaining | Baseline start | Baseline finish | Baseline duration | Total slack | Constraint | Resources | Work | Actual work | Text1 | Text2 | Text6 | Text7 | Text8 | Text3 | Text4 | Text5 | Text9 |
| --- | --- | --- | --- | --- | --- | --- | --- | --- | --- | --- | --- | --- | --- | --- | --- | --- | --- | --- | --- | --- | --- | --- | --- | --- |
| 129 | 19 | **Rel-6 MExE enhancements** | 326d | 2002-03-08 A | 2003-06-06 A | 100% |  | 2002-03-08 | 2003-06-06 | 326d |  |  | T2 | 7328h | 7328h | MEXE6 | Ter | Rel-6 | TSG | Friedhelm |  |  |  |  |
| 130 | 19.1 | MExE Rel-6 Improvements and Investigations | 264d | 2002-03-08 A | 2003-03-12 A | 100% |  | 2002-03-08 | 2003-03-12 | 264d |  | finish no earlier than 2003-03-12 | T2 | 2112h | 2112h | MEXE6-ENHANC | Ter | Rel-6 | TSG |  | 22.057, 23.057 | Lars Brenk (TTPCom) | lsb_ttpcom@HOTMAIL.COM |  |
| 131 | 19.2 | MExE Run-Time Independent Framework Feasibility Study | 326d | 2002-03-08 A | 2003-06-06 A | 100% |  | 2002-03-08 | 2003-06-06 | 326d |  | finish no earlier than 2003-06-06 | T2 | 2608h | 2608h | MEXE6-RTIF | Ter | Rel-6 | TSG |  | 22.857 | Aaron Cohen (Intel) | Aaron.Cohen@intel.com |  |
| 132 | 21 | Subscription Management | 841d | 2000-12-29 A | 2004-03-19 | 60% | 336.4d | 2000-12-29 | 2004-03-19 | 841d | 205d | finish no earlier than 2004-03-19 | S5 | 6728h | 4036.8h | SM |  | Rel-6 | TSG | Adrian | 32.140/1, 32.171/2 | Istvan ABA (T-Mobile Austria) | istvan.aba@t-mobile.at |  |
| 133 | 22 | **Support of Presence Capability** | 780d? | 2001-03-19 A | 2004-03-12 | 76% | 184.15d? | 2001-03-19 | 2003-12-19 | 720d? | 210d |  | S1 | 19696h | 15046h | PRESNC |  | Rel-6 | TSG | Michael |  | Mark Cataldo, Motorola |  | 11004 |
| 134 | 22.1 | Stage 1 | 610d | 2001-03-19 A | 2003-07-18 | 95% | 30.5d | 2001-03-19 | 2003-07-18 | 610d | 380d | finish no earlier than 2003-07-18 | S1 | 4880h | 4636h |  |  | Rel-6 |  |  |  |  |  | 11005 |
| 135 | 22.2 | Stage 2 | 268d | 2001-09-12 A | 2002-09-20 A | 100% |  | 2001-09-12 | 2002-09-20 | 268d |  | finish no earlier than 2002-09-20 | S2 | 2144h | 2144h |  |  | Rel-6 | TSG |  |  |  |  |  |
| 136 | 22.3 | Stage 3 | 510d | 2002-04-01 A | 2004-03-12 | 80% | 102d | 2002-04-01 | 2003-12-19 | 450d | 210d | finish no earlier than 2004-03-12 | N1 | 4080h | 3264h |  |  | Rel-6 |  |  |  | Keith Drage, Lucent | drage@lucent.com |  |
| 137 | 18.4 | Media Codecs and Formats for IMS Messaging and Presence | 136d? | 2003-06-12 A | 2003-12-18 | 10% | 122.4d? | 2003-06-12 | 2003-12-18 | 136d? | 271d | finish no earlier than 2003-12-18 | S4 | 1088h | 108.8h | COFIMP |  | Rel-6 | TSG | Paolo | TS 26.141 | Harri Honko (Nokia) | harri.honko@nokia.com |  |
| 138 | 22.4 | Security issues | 79d | 2002-08-26 A | 2002-12-12 | 20% | 63.2d | 2002-08-26 | 2002-12-12 | 79d | 536d | finish no earlier than 2002-12-12 | S3 | 632h | 126.4h |  |  | Rel-6 |  |  |  |  |  |  |
| 139 | 22.5 | USIM issues | 79d | 2002-03-04 | 2002-06-20 |  |  | 2002-03-04 | 2002-06-20 | 79d | 661d | start no earlier than 2002-03-04 | T3 | 632h |  |  |  | Rel-6 |  |  |  |  |  |  |
| 140 | 25 | **Enhanced A/Gb feasibility study** | 51d? | 2002-08-30 A | 2002-11-08 | 75% | 12.75d? | 2002-08-30 | 2002-11-08 | 51d? | 560d |  | GP | 4080h | 3162h | AGbEnFS |  | Rel-6 | TSG | Paolo |  | J-L Carrizo, Vodafone | jose-luis.carrizo@vodafone.co.uk |  |
| 141 | 25.1 | **Feasibility study on A/Gb enhancements** | 51d? | 2002-08-30 A | 2002-11-08 | 75% | 12.75d? | 2002-08-30 | 2002-11-08 | 51d? | 560d |  | G2 | 3672h | 2856h | AGbEnFS-FS |  | Rel-6 | TSG |  |  |  |  |  |
| 142 | 25.1.1 | Requirements for the support of conversational services | 51d | 2002-08-30 A | 2002-11-08 A | 100% |  | 2002-08-30 | 2002-11-08 | 51d |  | finish no earlier than 2002-11-08 | GP | 408h | 408h |  |  | Rel-6 |  |  |  |  |  |  |
| 143 | 19.1.2 | Identification of the different building blocks for the provision of conversational services on the existing A/Gb protocol stack | 51d? | 2002-08-30 A | 2002-11-08 A | 100% |  | 2002-08-30 | 2002-11-08 | 51d? |  | finish no earlier than 2002-11-08 | GP | 408h | 408h |  |  | Rel-6 |  |  |  |  |  |  |
| 144 | 19.1.3 | Outline of impact and feasibility of these building blocks and their different solutions | 51d? | 2002-08-30 A | 2002-11-08 A | 100% |  | 2002-08-30 | 2002-11-08 | 51d? |  | finish no earlier than 2002-11-08 | GP | 408h | 408h |  |  | Rel-6 |  |  |  |  |  |  |
| 145 | 25.1.2 | Identification of the different building blocks for the provision of conversational services on the existing A/Gb protocol stack | 51d | 2002-08-30 | 2002-11-08 |  |  | 2002-08-30 | 2002-11-08 | 51d | 560d | finish no earlier than 2002-11-08 | G2 | 408h |  |  |  | Rel-6 |  |  |  |  |  |  |
| 146 | 25.1.3 | Outline of impact and feasibility of these building blocks and their different solutions | 51d | 2002-08-30 | 2002-11-08 |  |  | 2002-08-30 | 2002-11-08 | 51d | 560d | finish no earlier than 2002-11-08 | G2 | 408h |  |  |  | Rel-6 |  |  |  |  |  |  |
| 147 | 25.1.4 | Impact on 3GPP architecture and requirement to co-ordinatge with other TSGs (CN, SA) | 51d | 2002-08-30 A | 2002-11-08 A | 100% |  | 2002-08-30 | 2002-11-08 | 51d |  | finish no earlier than 2002-11-08 | GP | 408h | 408h |  |  | Rel-6 |  |  |  |  |  |  |
| 148 | 25.1.5 | Standardisation effort | 51d | 2002-08-30 A | 2002-11-08 A | 100% |  | 2002-08-30 | 2002-11-08 | 51d |  | finish no earlier than 2002-11-08 | GP | 408h | 408h |  |  | Rel-6 |  |  |  |  |  |  |
| 149 | 25.1.6 | Dependency to other features | 51d | 2002-08-30 A | 2002-11-08 A | 100% |  | 2002-08-30 | 2002-11-08 | 51d |  | finish no earlier than 2002-11-08 | GP | 408h | 408h |  |  | Rel-6 |  |  |  |  |  |  |
| 150 | 26 | **Flexible Layer One for GERAN** | 1065d | 2000-01-03 A | 2004-01-30 | 53% | 503.32d | 2000-01-03 | 2003-11-21 | 1015d | 240d |  | GP | 77767h | 29565.4h | FLOGER |  | Rel-6 | TSG | Paolo |  | Benoist Sébire | benoist.sebire@nokia.com |  |
| 151 | 26.1 | **Realisation of a Flexible Layer One** | 1015d | 2000-01-03 A | 2003-11-21 | 65% | 355.25d | 2000-01-03 | 2003-06-27 | 910d | 290d |  | GP | 36208h | 21169.2h | FLOGER-Real |  | Rel-6 |  |  |  | Benoist Sébire | benoist.sebire@nokia.com |  |
| 152 | 26.1.1 | Technical Report | 416d | 2002-04-19 A | 2003-11-21 | 65% | 145.6d | 2002-04-19 | 2003-06-27 | 311d | 290d | finish no earlier than 2003-11-21 | GP | 3328h | 2163.2h |  |  | Rel-6 |  |  |  |  |  |  |
| 153 | 26.1.2 | Architecture in 45.001 and 43.051 | 416d | 2002-04-19 A | 2003-11-21 | 65% | 145.6d | 2002-04-19 | 2003-06-27 | 311d | 290d | finish no earlier than 2003-11-21 | G1 | 3328h | 2163.2h |  |  | Rel-6 |  |  |  |  |  |  |
| 154 | 26.1.3 | Multiplexing in 45.002 | 416d | 2002-04-19 A | 2003-11-21 | 65% | 145.6d | 2002-04-19 | 2003-06-27 | 311d | 290d | finish no earlier than 2003-11-21 | G1 | 3328h | 2163.2h |  |  | Rel-6 |  |  |  |  |  |  |
| 155 | 26.1.4 | Channel Coding in 45.003 | 416d | 2002-04-19 A | 2003-11-21 | 65% | 145.6d | 2002-04-19 | 2003-06-27 | 311d | 290d | finish no earlier than 2003-11-21 | G1 | 3328h | 2163.2h |  |  | Rel-6 |  |  |  |  |  |  |
| 156 | 26.1.5 | Performance Requirements in 45.005 | 1015d | 2000-01-03 A | 2003-11-21 | 65% | 355.25d | 2000-01-03 | 2003-06-27 | 910d | 290d | finish no earlier than 2003-11-21 | G1 | 8120h | 5278h |  |  | Rel-6 |  |  |  |  |  |  |
| 157 | 26.1.6 | Radio subsystem link control in 45.008 | 416d | 2002-04-19 A | 2003-11-21 | 65% | 145.6d | 2002-04-19 | 2003-06-27 | 311d | 290d | finish no earlier than 2003-11-21 | G1 | 3328h | 2163.2h |  |  | Rel-6 |  |  |  |  |  |  |
| 158 | 26.1.7 | Requirements in 44.004 | 416d | 2002-04-19 A | 2003-11-21 | 65% | 145.6d | 2002-04-19 | 2003-06-27 | 311d | 290d | finish no earlier than 2003-11-21 | G2 | 3328h | 2163.2h |  |  | Rel-6 |  |  |  |  |  |  |

Notes:
- 132: az: TSG appr. 9/03=>3/04. New TSs 32.171/2. Changed Rapp: Michael Eder (Nokia)=> Istvan ABA (T-Mobile Austria).
- 133: A Sultan merged "Presence Service Enhancements" (UID31028, PRES1) to this feature as no answer was provided on why Presence and Presence Encmts had same target completion date
- 137: Also for 31022 IMS Messaging
- 138: LSs handled in SA3. WID approved SA#17 Contribution at S3#25 & following e-mail discussion.
- 140: Closed
- 150: Nokia, Ericsson, Siemens, Telia
- 151: Started

| ID | WBS | Task | Duration | Start | Finish | Complete | Remaining | Baseline start | Baseline finish | Baseline duration | Total slack | Constraint | Resources | Work | Actual work | Text1 | Text4 | Text5 | Text6 | Text3 | Text8 | Text7 | Text9 |
| --- | --- | --- | --- | --- | --- | --- | --- | --- | --- | --- | --- | --- | --- | --- | --- | --- | --- | --- | --- | --- | --- | --- | --- |
| 159 | 26.2 | **Signalling and protocol support for a Flexible Layer One** | 416d | 2002-04-19 A | 2003-11-21 | 30% | 291.2d | 2002-04-19 | 2003-06-27 | 311d | 290d |  | G2 | 9984h | 2995.2h | FLOGER-SigPro | Benoist Sébire | benoist.sebire@nokia.com | Rel-6 |  |  |  |  |
| 160 | 26.2.1 | Modifications to RLC/MAC in 44.060 and 44.160 | 416d | 2002-04-19 A | 2003-11-21 | 30% | 291.2d | 2002-04-19 | 2003-06-27 | 311d | 290d | finish no earlier than 2003-11-21 | G2 | 3328h | 998.4h |  |  |  | Rel-6 |  |  |  |  |
| 161 | 26.2.2 | Modifications to RRC in 44.118 and 44.018 | 416d | 2002-04-19 A | 2003-11-21 | 30% | 291.2d | 2002-04-19 | 2003-06-27 | 311d | 290d | finish no earlier than 2003-11-21 | G2 | 3328h | 998.4h |  |  |  | Rel-6 |  |  |  |  |
| 162 | 26.3 | **Security for a Flexible Layer One** | 356d | 2002-04-19 A | 2003-08-29 | 99% | 0d | 2002-04-19 | 2003-06-27 | 311d | 0d |  | S3, G2 | 5663.04h | 2970.75h | FLOGER-SecFLO | Benoist Sébire | benoist.sebire@nokia.com | Rel-6 |  |  |  |  |
| 163 | 26.3.1 | Ciphering in 44.160,44.118, 44.060 and 44.018 | 356d | 2002-04-19 A | 2003-08-29 A | 100% |  | 2002-04-19 | 2003-06-27 | 311d |  | finish no earlier than 2003-08-29 | S3, G2 | 2848h | 2848h |  |  |  | Rel-6 |  |  |  |  |
| 164 | 26.4 | **GERAN MS Conformance test for the Flexible Layer One** | 310.5d | 2002-11-22 | 2004-01-30 |  |  | 2002-11-22 | 2003-11-21 | 260.5d | 240d |  | G4; G5 | 9936h |  | FLOGER-Msconf | Benoist Sébire | benoist.sebire@nokia.com | Rel-6 |  |  |  |  |
| 165 | 26.4.1 | MS Test in 51.010 | 310.5d | 2002-11-22 | 2004-01-30 |  |  | 2002-11-22 | 2003-11-21 | 260.5d | 240d | finish no earlier than 2004-01-30 | G4; G5 | 4968h |  |  |  |  | Rel-6 |  |  |  |  |
| 166 | 26.5 | **GERAN BTS Conformance test for the Flexible Layer One** | 466d | 2002-04-19 | 2004-01-30 |  |  | 2002-04-19 | 2003-11-21 | 416d | 240d |  | G3 | 7456h |  | FLOGER-BTSconf | Benoist Sébire | benoist.sebire@nokia.com | Rel-6 |  |  |  |  |
| 167 | 26.5.1 | BTS Test in 51.021 | 466d | 2002-04-19 | 2004-01-30 |  |  | 2002-04-19 | 2003-11-21 | 416d | 240d | finish no earlier than 2004-01-30 | G3 | 3728h |  |  |  |  | Rel-6 |  |  |  |  |
| 168 | 27 | Uplink TDOA feasibility study | 151d | 2001-11-30 A | 2002-06-28 A | 100% |  | 2001-11-30 | 2002-06-28 | 151d |  | finish no earlier than 2002-06-28 | GP | 1208h | 1208h | TDOAF | Bob Gross, TruePosition, Inc. | rlgross@trueposition.com | Rel-6 | 45.811 | Paolo |  |  |
| 169 | 28 | **Multimedia Broadcast and Multicast Service** | 746d? | 2001-05-11 A | 2004-03-19 | 29% | 531.08d? | 2001-05-11 | 2004-03-19 | 746d | 205d |  | S1 | 61681.6h | 15408.3h | MBMS |  |  | Rel-6 |  | Michael | TSG |  |
| 170 | 28.1 | Stage 1 | 232d | 2001-05-11 A | 2002-04-01 A | 100% |  | 2001-05-11 | 2002-04-01 | 232d |  | finish no earlier than 2002-04-01 | S1 | 1856h | 1856h |  |  |  | Rel-6 | 22.146, 22.101 |  |  | 11003 |
| 171 | 28.2 | **Stage 2** | 593d | 2001-09-24 A | 2003-12-31 | 91% | 53.25d | 2001-09-24 | 2003-09-19 | 520d | 262d |  | S2 | 9528h | 5679.2h |  |  |  | Rel-6 |  |  | TSG |  |
| 172 | 28.2.1 | TR on Architectural Study | 240d | 2001-09-24 A | 2002-08-23 A | 100% |  | 2001-09-24 | 2002-08-23 | 240d |  | finish no earlier than 2002-08-23 | S2 | 1920h | 1920h |  |  |  | Rel-6 |  |  |  |  |
| 173 | 28.2.2 | Stage 2 Specification Work | 358d | 2002-08-19 A | 2003-12-31 | 85% | 53.7d | 2002-08-19 | 2003-09-19 | 285d | 262d | finish no earlier than 2003-12-31 | S2 | 2864h | 2434.4h |  |  |  | Rel-6 |  |  |  |  |
| 174 | 28.3 | Introduction of MBMS in RAN | 579d | 2002-01-01 A | 2004-03-19 | 40% | 347.4d | 2002-01-01 | 2004-03-19 | 579d | 205d | finish no earlier than 2004-03-19 | R2 | 4632h | 1852.8h | MBMS-RAN | Juho Pirskanen , Nokia | juho.pirskanen@nokia.com | Rel-6 |  |  | TSG | 2481 |
| 175 | 28.4 | Support of the MBMS in CN protocols | 454d | 2002-06-18 A | 2004-03-12 | 25% | 340.5d | 2002-06-18 | 2003-12-12 | 389d | 210d | finish no earlier than 2004-03-12 | N1 | 3632h | 908h |  |  |  | Rel-6 |  |  | TSG |  |
| 176 | 22.5 | Gmb interface for MBMS (CN3 part) | 146d | 2003-08-29 A | 2004-03-19 | 10% | 131.4d |  |  |  | 205d | finish no earlier than 2004-03-19 | N3 | 1168h | 116.8h |  |  |  | Rel-6 |  |  |  |  |
| 177 | 28.5 | Security Aspects of Multimedia Broadcast/Multicast Service (MBMS) | 324d | 2002-07-01 A | 2003-09-25 | 20% | 259.2d | 2002-07-01 | 2003-02-28 | 175d | 331d | finish no earlier than 2003-09-25 | S3 | 2592h | 518.4h | MBMS | Escott, Adrian, 3 | adrian.escott@three.co.uk | Rel-6 |  |  | TSG |  |
| 178 | 28.6 | **Support of MBMS in GERAN** | 376d | 2002-08-30 A | 2004-02-06 | 15% | 319.38d | 2002-08-30 | 2003-11-21 | 321d | 235d |  | GP | 30976h | 4396.68h | MBMS-GERAN |  |  | Rel-6 |  |  | TSG |  |
| 179 | 28.6.1 | Impact on the logical and physical channels | 376d | 2002-08-30 A | 2004-02-06 | 20% | 300.8d | 2002-08-30 | 2003-11-21 | 321d | 235d | finish no earlier than 2004-02-06 | GP | 3008h | 601.6h |  |  |  | Rel-6 |  |  |  |  |
| 180 | 28.6.2 | Simultaneous support of MBMS services | 216d | 2002-08-30 | 2003-06-27 |  |  | 2002-08-30 | 2003-06-27 | 216d | 395d | finish no earlier than 2003-06-27 | G1 | 1728h |  |  |  |  | Rel-6 |  |  |  |  |
| 181 | 28.6.3 | Simultaneous support of MBMS and non-MBMS services | 216d | 2002-08-30 | 2003-06-27 |  |  | 2002-08-30 | 2003-06-27 | 216d | 395d | finish no earlier than 2003-06-27 | G1 | 1728h |  |  |  |  | Rel-6 |  |  |  |  |
| 182 | 28.6.4 | Re-synchronisation at cell change | 216d | 2002-08-30 | 2003-06-27 |  |  | 2002-08-30 | 2003-06-27 | 216d | 395d | finish no earlier than 2003-06-27 | G2 | 1728h |  |  |  |  | Rel-6 |  |  |  |  |
| 183 | 28.6.5 | Decision making process between point-to-point or pont-to-multipoint configurations | 376d | 2002-08-30 A | 2004-02-06 | 20% | 300.8d | 2002-08-30 | 2003-11-21 | 321d | 235d | finish no earlier than 2004-02-06 | GP | 3008h | 601.6h |  |  |  | Rel-6 |  |  |  |  |
| 184 | 28.6.6 | MBMS channel allocations procedures to multiple MSs | 376d | 2002-08-30 A | 2004-02-06 | 20% | 300.8d | 2002-08-30 | 2003-11-21 | 321d | 235d | finish no earlier than 2004-02-06 | GP | 3008h | 601.6h |  |  |  | Rel-6 |  |  |  |  |
| 185 | 28.6.7 | Changes to the Gb interface | 376d | 2002-08-30 A | 2004-02-06 | 20% | 300.8d | 2002-08-30 | 2003-11-21 | 321d | 235d | finish no earlier than 2004-02-06 | GP | 3008h | 601.6h |  |  |  | Rel-6 |  |  |  |  |
| 186 | 28.6.8 | GERAN specific changes to the Iu-ps interface | 376d | 2002-08-30 A | 2004-02-06 | 20% | 300.8d | 2002-08-30 | 2003-11-21 | 321d | 235d | finish no earlier than 2004-02-06 | GP | 3008h | 601.6h |  |  |  | Rel-6 |  |  |  |  |
| 187 | 28.6.9 | Interaction between MBMS and Iu-flex | 376d | 2002-08-30 A | 2004-02-06 | 20% | 300.8d | 2002-08-30 | 2003-11-21 | 321d | 235d | finish no earlier than 2004-02-06 | GP | 3008h | 601.6h |  |  |  | Rel-6 |  |  |  |  |
| 188 | 28.6.10 | Security aspects | 376d | 2002-08-30 A | 2004-02-06 | 20% | 300.8d | 2002-08-30 | 2003-11-21 | 321d | 235d | finish no earlier than 2004-02-06 | GP | 3008h | 601.6h |  |  |  | Rel-6 |  |  |  |  |
| 189 | 28.6.11 | MS conformance tests | 216d | 2002-08-30 | 2003-06-27 |  |  | 2002-08-30 | 2003-06-27 | 216d | 395d | finish no earlier than 2003-06-27 | G5 | 1728h |  |  |  |  | Rel-6 |  |  |  |  |
| 190 | 22.8 | Definition of MBMS user services, media codecs, formats and transport/application protocols using MBMS | 201d? | 2003-06-12 A | 2004-03-18 | 5% | 190.95d? | 2003-06-12 | 2004-03-18 | 201d? | 206d | finish no earlier than 2004-03-18 | S4 | 1608h | 80.4h | MBMS-TSMBMS | Igor Curcio (Nokia) | igor.curcio@nokia.com | Rel-6 |  |  | TSG |  |

Notes:
- 159: Started
- 162: Started
- 164: Not started
- 166: Not started
- 169: Title renamed at SA#13
- 170: This may or may not be a separate stage 1. In the meantime, CRs are proposed for 22.101
- 177: WID approved SA#17

| ID | WBS | Task | Duration | Start | Finish | Complete | Remaining | Baseline start | Baseline finish | Baseline duration | Total slack | Constraint | Resources | Work | Actual work | Text1 | Text6 | Text7 | Text8 | Text3 | Text4 | Text5 |
| --- | --- | --- | --- | --- | --- | --- | --- | --- | --- | --- | --- | --- | --- | --- | --- | --- | --- | --- | --- | --- | --- | --- |
| 191 | 29 | **Speech Recognition and Speech Enabled Services** | 670d? | 2001-10-08 A | 2004-04-30 | 32% | 452.67d? | 2001-10-08 | 2003-12-09 | 567d? | 175d |  | S1 | 11776h | 3819.86h | SRSES | Rel-6 | TSG | Michael |  |  |  |
| 192 | 29.1 | Speech Enabled Services Based on Distributed Speech Recognition (DSR) | 115d | 2001-10-08 A | 2002-03-15 | 95% | 5.75d | 2001-10-08 | 2002-03-15 | 115d | 730d | finish no earlier than 2002-03-15 | S1 | 920h | 874h | DSR | Rel-6 | TSG |  | 22.941, 23.207, 22.243 | D Williams, QUALCOMM, Inc. | Dwilliams@qualcomm.com |
| 193 | 29.2 | TR on Architectural impacts | 255d | 2003-05-12 A | 2004-04-30 | 25% | 191.25d | 2003-05-12 | 2003-12-09 | 152d | 175d | finish no earlier than 2004-04-30 | S2 | 2040h | 510h |  | Rel-6 |  |  |  |  |  |
| 194 | 29.3 | SES codec negotiation at SDP | 183d | 2002-09-23 | 2003-06-04 |  |  | 2002-09-23 | 2003-06-04 | 183d | 412d | finish no earlier than 2003-06-04 | N1 | 1464h |  |  | Rel-6 |  |  |  |  |  |
| 195 | 23.4 | Codec Work to Support Speech Recognition Framework for Automated Voice Services | 249d? | 2002-10-15 A | 2003-09-26 | 35% | 161.85d? | 2002-10-15 | 2003-09-26 | 249d? | 330d | finish no earlier than 2003-09-26 | S4 | 1992h | 697.2h | SRSES-Codec | Rel-6 | WG |  | 22.243 | David Pearce, Motorola | bdp003@motorola.com |
| 196 | 30 | **Generic User Profile** | 648d | 2001-10-08 A | 2004-03-31 | 42% | 376.24d | 2001-10-08 | 2003-12-12 | 570d | 197d |  | S1 | 25495.8h | 10692.4h | GUP | Rel-6 | TSG | Michael |  |  |  |
| 197 | 30.1 | Stage 1 - Requirements | 430d | 2001-10-08 A | 2003-05-30 | 88% | 50d | 2001-10-08 | 2003-05-30 | 430d | 415d | finish no earlier than 2002-12-09 | S1 | 3440h | 3040h |  | Rel-6 |  |  | 22.240, 22.228 | Paul Amery (Orange) | paul.amery@orange.co.uk |
| 198 | 30.2 | Stage 2 - Data Description Method | 648d | 2001-10-08 A | 2004-03-31 | 17% | 536.1d | 2001-10-08 | 2003-12-10 | 568d | 197d | finish no earlier than 2003-03-12 | T2 | 5184h | 895.2h |  | Rel-6 | WG |  | 23.241 | Kurt Bischinger (T-Mobile AUSTRIA) | kurt.bischinger@t-mobile.at |
| 199 | 30.3 | Stage 2 - Architecture | 355d | 2002-01-28 A | 2003-06-06 A | 100% |  | 2002-01-28 | 2003-06-06 | 355d |  | finish no earlier than 2003-06-06 | S2 | 2840h | 2840h |  | Rel-6 |  |  | 23.240 | Nacho Uzquiano (Telefonica) | uzquiano_ji@tsm.es |
| 200 | 30.4 | Stage 3 - Common objects | 648d | 2001-10-08 A | 2004-03-31 | 23% | 498.8d | 2001-10-08 | 2003-12-10 | 568d | 197d | finish no earlier than 2003-03-12 | T2 | 5184h | 1193.6h |  | Rel-6 | WG |  | 24.241 |  |  |
| 201 | 30.5 | Stage 3 - Network | 149.98d | 2003-05-19 A | 2003-12-12 | 15% | 127.48d | 2003-05-19 | 2003-12-12 | 149.98d | 275d | finish no earlier than 2003-12-12 | N4 | 1199.84h | 179.97h |  | Rel-6 |  |  | 29.240 |  |  |
| 202 | 30.6 | Security Aspects | 308d | 2002-07-16 A | 2003-09-18 | 15% | 261.8d | 2002-07-16 | 2003-09-18 | 308d | 336d | finish no earlier than 2003-09-18 | S3 | 2464h | 369.6h |  | Rel-6 | WG |  | 33.102, 33.203, 33.210 | Owen, Bradley | bvowen@lucent.com |
| 203 | 31 | **Digital Rights Management** | 380d? | 2001-10-08 A | 2003-03-21 | 49% | 194.82d? | 2001-10-08 | 2003-03-21 | 380d? | 465d |  | S1 | 7200h | 3508.61h | DRM | Rel-6 | TSG | Michael |  |  |  |
| 204 | 31.1 | Requirements | 179d | 2001-10-08 A | 2002-06-13 A | 100% |  | 2001-10-08 | 2002-06-13 | 179d |  | finish no earlier than 2002-06-13 | S1 | 1432h | 1432h |  | Rel-6 |  |  |  | Nicholas Wood, Openwave Systems | nicholas.wood@openwave.com |
| 205 | 25.2 | Monitoring of Stages 2 and 3 progress (actual work to be done by OMA) | 155d? | 2002-08-19 | 2003-03-21 |  |  | 2002-08-19 | 2003-03-21 | 155d? | 465d | start no earlier than 2002-08-19 | S1 | 1240h |  |  | Rel-6 |  |  |  |  |  |
| 206 | 31.3 | Security | 186d | 2002-06-17 A | 2003-03-03 | 40% | 111.6d | 2002-06-17 | 2003-03-03 | 186d | 479d | finish no earlier than 2003-03-03 | S3 | 1488h | 595.2h |  | Rel-6 |  |  |  |  |  |
| 207 | 32 | **WLAN-UMTS Interworking** | 1095d? | 2000-01-03 A | 2004-03-12 | 77% | 247.67d? | 2000-01-03 | 2003-12-12 | 1030d? | 210d |  | S1 | 30720h | 23771.7h | WLAN | Rel-6 | TSG | Michael |  | Fredric Paint, Telenor | frederic.paint@telenor.com |
| 208 | 32.1 | Technical Report | 900d? | 2000-01-03 A | 2003-06-13 | 99% | 9d? | 2000-01-03 | 2003-06-13 | 900d? | 405d | finish no earlier than 2003-06-13 | S1 | 7200h | 7128h | WLAN-TR | Rel-6 |  |  | 22.934, 22.101, 22.105 | Fredric Paint, Telenor | frederic.paint@telenor.com |
| 209 | 26.2 | CRs to implement WLAN | 900d? | 2000-01-03 A | 2003-06-13 | 85% | 135d? | 2000-01-03 | 2003-06-13 | 900d? | 405d | finish no earlier than 2003-06-13 | S1 | 7200h | 6120h | WLAN-CR | Rel-6 |  |  | 22.934, 22.101, 22.105, 22.115 | Fredric Paint, Telenor | frederic.paint@telenor.com |
| 210 | 32.2 | Architecture Definition | 463d | 2002-03-25 A | 2003-12-31 | 86% | 64.82d | 2002-03-25 | 2003-09-26 | 395d | 262d | finish no earlier than 2003-12-31 | S2 | 3704h | 3185.44h |  | Rel-6 | TSG |  |  |  |  |
| 211 | 32.3 | Security | 125d | 2002-09-30 A | 2003-03-21 | 30% | 87.5d | 2002-09-30 | 2003-03-21 | 125d | 465d | finish no earlier than 2003-03-21 | S3 | 1000h | 300h |  | Rel-6 | TSG |  | 21.133, 33.106, 33.107, 33.108, 33.200, 33.203, 33.210 | Lopez-Soria, Luis, Ericsson | luis.lopez-soria@ece.ericsson.se |
| 212 | 26.5 | Stage 3 - CN4 aspects | 146d? | 2003-05-23 A | 2003-12-12 | 15% | 124.1d? | 2003-05-23 | 2003-12-12 | 146d? | 275d | finish no earlier than 2003-12-12 | N4 | 1168h | 175.2h | WLAN-IW | Rel-6 | TSG |  | 29.234, 29.061 | Rodriguez ,Raquel, Nokia | raquel.rodriguez@nokia.com |
| 213 | 26.6 | WLAN interworking- stage 3 | 211d? | 2003-05-23 A | 2004-03-12 | 5% | 200.45d? | 2003-05-23 | 2003-12-12 | 146d? | 210d | finish no earlier than 2004-03-12 | N1 | 1688h | 84.4h |  | Rel-6 | WG |  |  |  |  |
| 214 | 33 | **Priority Service** | 347d? | 2002-05-30 A | 2003-09-26 | 52% | 165.04d? | 2002-05-30 | 2003-09-26 | 347d? | 330d |  | S1 | 7512h | 3939.13h | PRIOR | Rel-6 | TSG | Michael |  |  |  |
| 215 | 33.1 | Feasibility Study | 1d | 2002-06-14 A | 2002-06-14 A | 100% |  | 2002-06-14 | 2002-06-14 | 1d |  | finish no earlier than 2002-06-14 | S1 | 8h | 8h | PRIOR-FS | Rel-6 |  | Michael | 22.950 | Biplab K. Pramanik, Telcordia Technologies | bpramani@telcordia.com |
| 216 | 33.2 | Stage 1 - Requirements | 340d | 2002-05-30 A | 2003-09-17 | 85% | 51d | 2002-05-30 | 2003-09-17 | 340d | 337d | finish no earlier than 2003-09-17 | S1 | 2720h | 2312h | PRIOR-SR | Rel-6 |  | Michael |  | James J. Garrahan, Telcordia Technologies | bpramani@telcordia.com |
| 217 | 27.3 | Priority Multimedia Service | 131d? | 2003-03-28 | 2003-09-26 |  |  | 2003-03-28 | 2003-09-26 | 131d? | 330d | finish no earlier than 2003-09-26 | S1 | 1048h |  |  | Rel-6 |  |  |  |  |  |
| 218 | 27.4 | Priority service implementation guide | 131d? | 2003-03-28 A | 2003-09-26 | 20% | 104.8d? | 2003-03-28 | 2003-09-26 | 131d? | 330d | finish no earlier than 2003-09-26 | S1 | 1048h | 209.6h |  | Rel-6 |  |  | 22.952 | Biplab K. Pramanik, Telcordia Technologies | bpramani@telcordia.com |

Notes:
- 194: renamed according to Hannu's indication
- 201: 17 May no activity in CN4 / 02/08/2002 CN4: No activity in CN4 / 12/03/2003CN#19: CN4 have agreed in principle to undertake this work, but there was no substantive input (WID or technical). There is concern over the immaturity of the stage 1 & stage 2 specifications; we believe that we will need 6 months from when the stage 2 specification is stable in order to do the stage 3 work. / 29/05/2003 CN4 : Outline of draft TS approved
- 202: WID approved SA#17. SA WG3 progress slow, depends on progress in other groups.
- 203: Foreseen start and completion dates introduced by MCC (no indication at all on the WID)
- 206: SA3 acknowledge role in WI at SA3#20. Active contribution S3#24, S3#25. S3 WID approved SA#17
- 211: Active contribution S3#24, S3#25. WID approved SA#17
- 212: WID approved at CN#19 / 29/05/2003 CN4: Outline of draft TS approved

| ID | WBS | Task | Duration | Start | Finish | Complete | Remaining | Baseline start | Baseline finish | Baseline duration | Total slack | Constraint | Resources | Work | Actual work | Text1 | Text6 | Text7 | Text8 | Text3 | Text4 | Text5 | Text9 | Text10 | Text11 | Text12 |
| --- | --- | --- | --- | --- | --- | --- | --- | --- | --- | --- | --- | --- | --- | --- | --- | --- | --- | --- | --- | --- | --- | --- | --- | --- | --- | --- |
| 219 | 34 | **Network Sharing** | 300d? | 2003-01-20 A | 2004-03-12 | 54% | 137.68d? | 2003-01-20 | 2003-12-19 | 240d? | 210d |  | S1 | 10616h | 5743.99h | NTShar | Rel-6 | TSG | Michael |  |  |  |  |  |  |  |
| 220 | 34.1 | Technical Report | 240d? | 2003-01-20 A | 2003-12-19 | 99% | 2.4d? | 2003-01-20 | 2003-12-19 | 240d? | 270d |  | S1 | 1920h | 1900.8h | NTShar-TR | Rel-6 |  | Michael | 22.951 |  |  |  |  |  |  |
| 221 | 28.2 | Stage 1 - CRs to implement Network Sharing | 240d? | 2003-01-20 A | 2003-12-19 | 95% | 12d? | 2003-01-20 | 2003-12-19 | 240d? | 270d | finish no earlier than 2003-12-19 | S1 | 1920h | 1824h | NTShar-CR | Rel-6 |  |  | 22.011, 22.101, 22.115, 22.129 |  |  |  |  |  |  |
| 222 | 28.3 | Stage 2 | 212d? | 2003-02-27 A | 2003-12-19 | 43% | 120.84d? | 2003-02-27 | 2003-12-19 | 212d? | 270d | finish no earlier than 2003-12-19 | S2 | 1696h | 729.28h |  | Rel-6 |  |  |  |  |  |  |  |  |  |
| 223 | 28.4 | Network sharing - stage 3 | 211d? | 2003-05-23 | 2004-03-12 |  |  | 2003-05-23 | 2003-12-12 | 146d? | 210d | finish no earlier than 2004-03-12 | N1 | 1688h |  |  | Rel-6 | WG |  |  |  |  |  |  |  |  |
| 224 | 28.5 | Enhancement of the support of network sharing in the UTRAN | 126d | 2003-09-19 | 2004-03-12 |  |  |  |  |  | 210d | start no earlier than 2003-09-19 | R2 | 1008h |  | NTShar-UTRANEnh | Rel-6 | TSG |  | TS25.401, TS25.413, TS25.331, TS25.304 | Anders Dahlén, TeliaSonera | Anders.Dahlen@TeliaSonera.com | BB | 31018 | Active | 48 |
| 225 | 35 | **QoS Improvements** | 440d? | 2002-07-15 A | 2004-03-19 | 49% | 222.76d? | 2000-01-03 | 2003-12-19 | 1035d? | 205d |  | S2 | 8680h | 4285.5h | QoS1 | Rel-6 | TSG | Sang-Ui |  |  |  |  |  |  |  |
| 226 | 35.1 | FS on Dynamic Policy control enhancements for end-to-end QoS | 375d | 2002-07-15 A | 2003-12-19 | 75% | 93.75d | 2002-07-15 | 2003-12-19 | 375d | 270d | finish no earlier than 2003-12-19 | S2 | 3000h | 2250h | QoS1 | Rel-6 | TSG |  |  |  | Claire Mousset, Nortel |  |  |  |  |
| 227 | 29.2 | Definition of the Gq interface | 124d? | 2003-07-01 A | 2003-12-19 | 30% | 86.8d? | 2000-01-03 | 2000-01-03 | 1d? | 270d | start no earlier than 2003-07-01 | S2 | 992h | 297.6h |  | Rel-6 |  |  |  | Janne Rinne (Nokia) |  |  |  |  |  |
| 228 | 29.3 | Gq interface specification for Dynamic Policy control enhancements – Stage 3 | 146d | 2003-08-29 | 2004-03-19 |  |  |  |  |  | 205d | finish no earlier than 2004-03-19 | N3 | 1168h |  |  | Rel-6 | TSG |  | 24,228, 29.207, 29.208 | Anna Sillanpää, Nokia | valtteri.niemi@nokia.com |  |  |  |  |
| 229 | 36 | **Support for subscriber certificates** | 613d? | 2002-02-25 A | 2004-06-30 | 22% | 478.54d? | 2002-02-25 | 2002-11-14 | 189d | 132d |  | S3 | 7880h | 1728.52h | SEC1-SC | Rel-6 | TSG | Maurice | 33.102 | Valtteri Niemi, Nokia | valtteri.niemi@nokia.com |  |  |  |  |
| 230 | 36.1 | Stage 1 | 144d | 2002-02-25 A | 2002-09-12 | 40% | 86.4d | 2002-02-25 | 2002-09-12 | 144d | 601d | finish no earlier than 2002-09-12 | S3 | 1152h | 460.8h |  | Rel-6 |  |  |  |  |  |  |  |  |  |
| 231 | 36.2 | Architecture review | 24d | 2002-10-14 A | 2002-11-14 A | 100% |  | 2002-10-14 | 2002-11-14 | 24d |  | finish no earlier than 2002-11-14 | S2 | 192h | 192h |  | Rel-6 |  |  |  |  |  |  |  |  |  |
| 232 | 30.3 | Stage 3 | 204d? | 2003-09-19 | 2004-06-30 |  |  |  |  |  | 132d | finish no earlier than 2004-06-30 | N4 | 1632h |  | SEC1-SC | Rel-6 |  | Kimmo |  | Lauri Laitinen, Nokia |  |  |  |  |  |
| 233 | 31 | **Rel-6 OSA enhancements** | 542.1d? | 2002-02-27 A | 2004-03-26 | 30% | 376.99d? | 2002-02-14 | 2003-12-19 | 481.85d? | 200d |  | S1 | 35816.8h | 10909.1h | OSA3 | Rel-6 | TSG | Adrian | 22.127, 29.198, 29.998 | Chelo ABARCA (Alcatel) | Chelo.Abarca@alcatel.fr |  |  |  |  |
| 234 | 31.1 | Scope of the Open Service Access Release 6 | 66d? | 2003-03-28 A | 2003-06-27 | 90% | 6.6d? | 2003-03-28 | 2003-06-27 | 66d? | 395d | finish no earlier than 2003-06-27 | S1 | 528h | 475.2h |  | Rel-6 | TSG |  |  |  |  |  |  |  |  |
| 235 | 38.11 | User Data Management / User data security management (Stage 1) | 212.1d | 2002-02-27 A | 2003-01-06 A | 100% |  | 2002-02-27 | 2003-01-06 | 212.1d |  | finish no earlier than 2003-01-06 | S1 | 1696.79h | 1696.79h |  | Rel-6 | TSG |  | 22.127 |  |  |  |  |  |  |
| 236 | 38.12 | User Data Management / User data security management (Stage 3) | 297d | 2002-10-31 | 2003-12-19 |  |  | 2002-03-14 | 2003-12-19 | 462d | 270d | start no earlier than 2002-10-31 | N5 | 2376h |  |  | Rel-6 | TSG |  | 29.198, 29.998 |  |  |  |  |  |  |
| 237 | 31.4 | Access to IP Session information | 297d? | 2002-10-31 | 2003-12-19 |  |  | 2002-10-31 | 2003-12-19 | 297d? | 270d | finish no earlier than 2003-12-19 | N5 | 2376h |  |  | Rel-6 | TSG |  | 29.198, 29.998 |  |  |  |  |  |  |
| 238 | 31.5 | Multi Media Messaging function | 367d? | 2002-10-31 A | 2004-03-26 | 50% | 183.5d? | 2002-10-31 | 2003-12-19 | 297d? | 200d | finish no earlier than 2004-03-26 | N5 | 2936h | 1468h |  | Rel-6 | TSG |  | 29.198, 29.998 |  |  |  |  |  |  |
| 239 | 31.6 | Policy management extensions | 367d? | 2002-10-31 A | 2004-03-26 | 40% | 220.2d? | 2002-10-31 | 2003-12-19 | 297d? | 200d | finish no earlier than 2004-03-26 | N5 | 2936h | 1174.4h |  | Rel-6 | TSG |  | 29.198, 29.998 |  |  |  |  |  |  |
| 240 | 31.7 | Presence and Availability Management (from the PRESNC WI) | 367d? | 2002-10-31 A | 2004-03-26 | 40% | 220.2d? | 2002-10-31 | 2003-12-19 | 297d? | 200d | finish no earlier than 2004-03-26 | N5 | 2936h | 1174.4h |  | Rel-6 | TSG |  | 29.198, 29.998 |  |  |  |  |  |  |
| 241 | 31.8 | OSA interfaces at different levels of abstractions (Parlay X, Web services) | 296d? | 2002-11-01 A | 2003-12-19 | 51% | 145d? | 2003-03-14 | 2003-12-19 | 201d? | 270d | start no earlier than 2002-11-01 | N5 | 2368h | 1208h |  | Rel-6 | TSG |  | 29.199 |  |  |  |  |  |  |
| 242 | 31.9 | Introduction of migration support mechanism | 304d? | 2002-11-01 A | 2003-12-31 | 50% | 153d? | 2003-03-14 | 2003-12-19 | 201d? | 262d | start no earlier than 2002-11-01 | N5 | 2432h | 1208h |  | Rel-6 | TSG |  | 29.198, 29.998 |  |  |  |  |  |  |
| 243 | 31.10 | User Profile | 367d? | 2002-10-31 | 2004-03-26 |  |  | 2003-03-14 | 2003-12-19 | 201d? | 200d | start no earlier than 2002-10-31 | N5 | 2936h |  |  | Rel-6 | TSG |  | 29.198, 29.998 |  |  |  |  |  |  |
| 244 | 31.11 | Network functions for end-user/application interaction support | 367d? | 2002-10-31 | 2004-03-26 |  |  | 2003-03-14 | 2003-12-19 | 201d? | 200d | start no earlier than 2002-10-31 | N5 | 2936h |  |  | Rel-6 | TSG |  | 29.198, 29.998 |  |  |  |  |  |  |
| 245 | 31.12 | Framework Function for Federation | 271d? | 2003-02-03 A | 2004-02-16 | 56% | 120d? | 2003-03-14 | 2003-12-19 | 201d? | 229d | start no earlier than 2003-02-01 | N5 | 2168h | 1208h |  | Rel-6 | TSG |  | 29.198, 29.998 |  |  |  |  |  |  |
| 246 | 31.13 | Enhancements to IP Session Function in OSA for the control and monitor of IP Flows | 367d? | 2002-10-31 | 2004-03-26 |  |  | 2003-03-14 | 2003-12-19 | 201d? | 200d | start no earlier than 2002-10-31 | N5 | 2936h |  |  | Rel-6 | TSG |  | 29.198, 29.998 |  |  |  |  |  |  |

Notes:
- 224: Approved at TSG RAN#21 as RP-030549
- 229: Approved at SA#14. This may require BBs from CN1, CN4, SA5 and T3
- 230: Contribution received S3#24, S3#25
- 232: WID approved at CN#21
- 233: NP-030036 Rev WID replaces SP-020573.
- 236: N5#24: Completion 60%->0%. Reason: No support from SA2.
- 237: N5#24: Completion 60%->0%. Reason: No support from SA2.
- 238: N5#24: Completion 60%->50%. Completion 12/03->03/04.
- 239: N5#24: Completion 60%->40%. Completion 12/03->03/04.
- 240: N5#24: Completion 60%->40%. Completion 12/03->03/04.
- 241: N5#24: Completion 40%->80%. Completion 12/03->03/04.
- 242: N5#24: Completion 60%->90%.
- 243: N5#24: Completion 60%->0%. Reason: No contributions. N5 suggests SA1 to remove requirement
- 244: N5#24: Completion 60%->0%. Reason: SA1 requirement may disappear
- 245: N5#24: Completion 60%->90%. N5 believes that current FW supports this requirement without changes.
- 246: N5#24: Completion 60%->0%. Reason: No reply from SA1, SA2

| ID | WBS | Task | Duration | Start | Finish | Complete | Remaining | Baseline start | Baseline finish | Baseline duration | Total slack | Constraint | Resources | Work | Actual work | Text1 | Text4 | Text6 | Text7 | Text8 | Text3 | Text5 | Text2 |
| --- | --- | --- | --- | --- | --- | --- | --- | --- | --- | --- | --- | --- | --- | --- | --- | --- | --- | --- | --- | --- | --- | --- | --- |
| 247 | 39 | **Addition of frequency bands to GSM** | 366d | 2002-06-28 A | 2003-11-21 | 7% | 341.72d | 2002-06-28 | 2003-08-29 | 306d | 290d |  | GP | 9200h | 610.2h | TAPS | Torben Themsen | Rel-6 | TSG | Paolo |  |  |  |
| 248 | 39.1 | **Addition of frequency bands to GSM – Changes to core specs** | 26d | 2002-11-15 A | 2002-12-20 A | 100% |  | 2002-11-15 | 2002-12-20 | 26d |  |  | G1 | 416h | 416h | TAPS-Specs | Torben Themsen | Rel-6 | TSG |  |  |  |  |
| 249 | 39.1.1 | Changes to core specs | 26d | 2002-11-15 A | 2002-12-20 A | 100% |  | 2002-11-15 | 2002-12-20 | 26d |  | finish no earlier than 2002-12-20 | G1 | 208h | 208h |  |  | Rel-6 |  |  |  |  |  |
| 250 | 39.2 | **Addition of frequency bands to GSM – Changes for conformance tests** | 366d | 2002-06-28 | 2003-11-21 |  |  | 2002-06-28 | 2003-08-29 | 306d | 290d |  | G4 | 5856h |  | TAPS-Conf | Torben Themsen | Rel-6 |  |  |  |  |  |
| 251 | 39.2.1 | 51.010-1 Add testing | 366d | 2002-06-28 | 2003-11-21 |  |  | 2002-06-28 | 2003-08-29 | 306d | 290d | finish no earlier than 2003-11-21 | G4 | 2928h |  |  |  | Rel-6 |  |  |  |  |  |
| 252 | 40 | **Seamless support of streaming services in A/Gb mode** | 1065d? | 2000-01-03 A | 2004-01-30 | 86% | 154.02d? | 2000-01-03 | 2003-12-19 | 1035d? | 240d |  | GP | 41088h | 27187.3h | SSStrea | José Luis Carrizo Martínez, Vodafone | Rel-6 | TSG | Paolo |  |  |  |
| 253 | 40.1 | **Identification of requirements for streaming** | 46d? | 2003-06-27 A | 2003-08-29 | 99% | 0d? | 2003-06-27 | 2003-06-27 | 1d? | 0d |  | G1 | 736h | 376h |  |  | Rel-6 |  |  |  |  |  |
| 254 | 33.1.1 | Requirements | 46d? | 2003-06-27 A | 2003-08-29 A | 100% |  | 2003-06-27 | 2003-06-27 | 1d? |  | finish no earlier than 2003-08-29 | G1 | 368h | 368h |  |  | Rel-6 |  |  |  |  |  |
| 255 | 40.2 | **Performance study of cell change mechanisms** | 955d? | 2000-01-03 A | 2003-08-29 | 99% | 0d? | 2000-01-03 | 2003-06-27 | 910d? | 0d |  | G1 | 30560h | 23012.8h |  |  | Rel-6 |  |  |  |  |  |
| 256 | 33.2.1 | Performance of NACC | 955d? | 2000-01-03 A | 2003-08-29 A | 100% |  | 2000-01-03 | 2003-06-27 | 910d? |  | finish no earlier than 2003-08-29 | G1 | 7640h | 7640h |  |  | Rel-6 |  |  |  |  |  |
| 257 | 33.2.2 | Performance of cell change in DTM for the PS domain | 955d? | 2000-01-03 A | 2003-08-29 A | 100% |  | 2000-01-03 | 2003-06-27 | 910d? |  | finish no earlier than 2003-08-29 | G1 | 7640h | 7640h |  |  | Rel-6 |  |  |  |  |  |
| 258 | 33.2.3 | Handover | 955d? | 2000-01-03 A | 2003-08-29 A | 100% |  | 2000-01-03 | 2003-06-27 | 910d? |  | finish no earlier than 2003-08-29 | G1 | 7640h | 7640h |  |  | Rel-6 |  |  |  |  |  |
| 259 | 40.3 | **Reduction of service interruption times and packet loss during mobility procedures** | 106d? | 2003-06-27 A | 2003-11-21 | 39% | 64.66d? | 2003-06-27 | 2003-06-27 | 1d? | 290d |  | G2 | 4240h | 1326.88h |  |  | Rel-6 |  |  |  |  |  |
| 260 | 33.3.1 | Optimisations of existing mechanisms/procedures | 106d? | 2003-06-27 A | 2003-11-21 | 39% | 64.66d? | 2003-06-27 | 2003-06-27 | 1d? | 290d | finish no earlier than 2003-11-21 | G2 | 848h | 330.72h |  |  | Rel-6 |  |  |  |  |  |
| 261 | 33.3.2 | Inter-system NACC | 106d? | 2003-06-27 A | 2003-11-21 | 39% | 64.66d? | 2003-06-27 | 2003-06-27 | 1d? | 290d | finish no earlier than 2003-11-21 | G2 | 848h | 330.72h |  |  | Rel-6 |  |  |  |  |  |
| 262 | 33.3.3 | PS Handover (within GERAN and between GERAN and UTRAN) | 106d? | 2003-06-27 A | 2003-11-21 | 39% | 64.66d? | 2003-06-27 | 2003-06-27 | 1d? | 290d | finish no earlier than 2003-11-21 | G2 | 848h | 330.72h |  |  | Rel-6 |  |  |  |  |  |
| 263 | 33.3.4 | Dependency to other features | 106d? | 2003-06-27 A | 2003-11-21 | 39% | 64.66d? | 2003-06-27 | 2003-06-27 | 1d? | 290d | finish no earlier than 2003-11-21 | G2 | 848h | 330.72h |  |  | Rel-6 |  |  |  |  |  |
| 264 | 40.5 | **MS conformance testing** | 31d? | 2003-12-19 | 2004-01-30 |  |  | 2003-12-19 | 2003-12-19 | 1d? | 240d |  | G4,G5 | 496h |  |  |  | Rel-6 |  |  |  |  |  |
| 265 | 33.4.1 | MS conformance tests | 31d? | 2003-12-19 | 2004-01-30 |  |  | 2003-12-19 | 2003-12-19 | 1d? | 240d | finish no earlier than 2004-01-30 | G4,G5 | 248h |  |  |  | Rel-6 |  |  |  |  |  |
| 266 | 33.5 | GERAN A/Gb mode security enhancements | 261d? | 2002-09-26 A | 2003-09-25 | 10% | 234.9d? | 2002-09-26 | 2003-09-25 | 261d? | 331d | finish no earlier than 2003-09-25 | S3 | 2088h | 208.8h |  | Peter Howard, Vodafone | Rel-6 |  |  | 33.102 | peter.howard@vodafone.com |  |
| 267 | 41 | Performance characterisation of default codecs for PS conversational multimedia application | 271d | 2002-09-13 A | 2003-09-26 | 35% | 176.15d | 2002-09-13 | 2003-09-26 | 271d | 330d | finish no earlier than 2003-09-26 | S4 | 2168h | 758.8h | CODCAR | Pasi Ojala (Nokia) | Rel-6 | TSG | Paolo | TR 26.9yz | pasi.s.ojala@nokia.com |  |
| 268 | 42 | Study of Feature Interactions Requirements | 82d | 2002-11-08 A | 2003-03-03 | 20% | 65.6d | 2002-11-08 | 2003-03-03 | 82d | 479d | start no earlier than 2002-11-08 | S1 | 656h | 131.2h | FINTER |  | Rel-6 | TSG | Michael | TR 21.xyz |  |  |
| 269 | 43 | Study on Privacy Capability | 82d | 2002-11-08 A | 2003-03-03 | 15% | 69.7d | 2002-11-08 | 2003-03-03 | 82d | 479d | start no earlier than 2002-11-08 | S1 | 656h | 98.4h | PrivCap | Liz Daniel, Lucent | Rel-6 | TSG | Michael | TR 21.xyz |  |  |
| 270 | 44 | **OAM&P** | 405d? | 2002-09-12 A | 2004-03-31 | 42% | 234.51d? | 2002-05-21 | 2004-03-18 | 477.3d? | 197d |  | S5 | 15949.6h | 6388.82h | OAM | Michael TRUSS (Motorola) | Rel-6 | TSG | Adrian | 32-series | Michael.Truss@MOTOROLA.COM |  |
| 271 | 44.1 | Principles, high level Requirements and Architecture | 396d | 2002-09-12 A | 2004-03-18 | 50% | 198d | 2002-09-12 | 2004-03-18 | 396d | 206d | finish no earlier than 2004-03-18 | S5 | 3168h | 1584h | OAM-AR | Michael TRUSS (Motorola) | Rel-6 | TSG |  | 32.101, 32.102 | Michael.Truss@MOTOROLA.COM | BCaM |
| 272 | 44.2 | Performance Management | 396d | 2002-09-12 A | 2004-03-18 | 50% | 198d | 2002-09-12 | 2004-03-18 | 396d | 206d | finish no earlier than 2004-03-18 | S5 | 3168h | 1584h | OAM-PM | Christian TOCHE (Nortel Networks) | Rel-6 | TSG |  | 32.41x, 52.402 | toche@NORTELNETWORKS.COM | BCaM |
| 273 | 44.4 | Network Infrastructure Management | 396d | 2002-09-12 A | 2004-03-18 | 40% | 237.6d | 2002-09-12 | 2004-03-18 | 396d | 206d | finish no earlier than 2004-03-18 | S5 | 3168h | 1267.2h | OAM-NIM | Thomas TOVINGER (Ericsson) | Rel-6 | TSG |  | 32.15x, 32.3/6/7xy | Thomas.Tovinger@emw.ericsson.se |  |

Notes:
- 248: Ready
- 250: Not started
- 253: Started
- 255: Started
- 259: Started
- 264: Not started
- 266: Possible changes to 33.102 or new specification needed.

| ID | WBS | Task | Duration | Start | Finish | Complete | Remaining | Baseline start | Baseline finish | Baseline duration | Total slack | Constraint | Resources | Work | Actual work | Text1 | Text3 | Text4 | Text5 | Text6 | Text7 | Text8 | Text2 | Text9 |
| --- | --- | --- | --- | --- | --- | --- | --- | --- | --- | --- | --- | --- | --- | --- | --- | --- | --- | --- | --- | --- | --- | --- | --- | --- |
| 274 | 44.5 | **Trace Management** | 214d? | 2003-06-06 A | 2004-03-31 | 15% | 181.42d? | 2003-06-06 | 2003-09-19 | 76d | 197d |  | S5 | 3328h | 641.2h | OAM-Trace | 32.42x, 52.008 | Kari RÖNKÄ (Nokia) | kari.t.ronka@nokia.com | Rel-6 | TSG |  |  |  |
| 275 | 37.4.1 | Subscriber and equipment trace in UTRAN | 201d? | 2003-06-06 A | 2004-03-12 | 15% | 170.85d? | 2003-06-06 | 2003-09-19 | 76d? | 210d | finish no earlier than 2004-03-12 | R3 | 1608h | 241.2h | OAM-Trace-RAN |  | Yann Sehedi, Nortel | sehedic@nortelnetworks.com | Rel-6 | TSG |  |  |  |
| 276 | 37.4.2 | Subscriber and UE trace management | 1d | 2004-03-31 A | 2004-03-31 | 60% | 0.4d |  |  |  | 197d | finish no earlier than 2004-03-31 | S5 | 8h | 4.8h | OAM-Trace | 32.42x, 52.008 | Kari RÖNKÄ (Nokia) | kari.t.ronka@nokia.com | Rel-6 | TSG |  |  |  |
| 277 | 38 | **Charging Management** | 346d? | 2002-11-21 A | 2004-03-18 | 58% | 144.34d? | 2002-11-21 | 2004-03-18 | 346d? | 206d |  | S5 | 13368h | 7791.27h | CH | 32.2xy | Karl-Heinz NENNER (T-Mobile) | karl-heinz.nenner@t-mobile.de | Rel-6 | TSG | Adrian |  |  |
| 278 | 38.1 | Charging Management for Bearer level | 345d? | 2002-11-22 A | 2004-03-18 | 55% | 155.25d? | 2002-11-22 | 2004-03-18 | 345d? | 206d | finish no earlier than 2004-03-18 | S5 | 2760h | 1518h | CH-BC |  | Benni ALEXANDER (Nokia) |  | Rel-6 | TSG |  |  |  |
| 279 | 38.2 | Charging Management for the IMS | 345d? | 2002-11-22 A | 2004-03-18 | 55% | 155.25d? | 2002-11-22 | 2004-03-18 | 345d? | 206d | finish no earlier than 2004-03-18 | S5 | 2760h | 1518h | CH-IC |  | Ariel SHARON (Lucent) |  | Rel-6 | TSG |  |  |  |
| 280 | 38.3 | Charging Management for the Service domain | 345d? | 2002-11-22 A | 2004-03-18 | 55% | 155.25d? | 2002-11-22 | 2004-03-18 | 345d? | 206d | finish no earlier than 2004-03-18 | S5 | 2760h | 1518h | CH-SC |  | Gerald GÖRMER (Siemens) |  | Rel-6 | TSG |  |  |  |
| 281 | 38.4 | Overall architectural aspects of IP flow based bearer level charging | 290d? | 2002-11-21 A | 2003-12-31 | 70% | 87d? | 2002-11-21 | 2003-09-26 | 222d? | 262d | finish no earlier than 2003-12-31 | S2 | 2320h | 1624h |  |  |  |  | Rel-6 |  |  |  |  |
| 282 | 13 | **Rel-6 UICC/USIM enhancements and interworking** | 836d | 2000-09-25 A | 2003-12-08 | 97% | 25.8d | 2000-09-25 | 2003-09-17 | 778d | 279d |  | T3 | 25488h | 21556.7h | USAT1 |  |  |  | Rel-6 | TSG | Claus | Ter | 1800 |
| 283 | 13.1 | **UICC API** | 449d | 2002-03-20 A | 2003-12-08 | 93% | 33.11d | 2002-03-20 | 2003-09-17 | 391d | 279d |  | T3 | 7736h | 7165.51h | USAT1-API |  |  |  | Rel-6 |  |  | Ter | 1802 |
| 284 | 13.1.1 | Java API Test specification | 59d | 2002-03-20 A | 2002-06-10 A | 100% |  | 2002-03-20 | 2002-09-20 | 133d |  | finish no earlier than 2002-09-20 | T3 | 472h | 472h |  |  | Mario Pérez (Microelectrónica Española) |  | Rel-6 |  |  |  |  |
| 285 | 13.1.2 | Java API Test specification (TS 43.019 Rel-5) | 268d | 2002-05-30 A | 2003-06-09 A | 100% |  | 2002-05-30 | 2003-09-17 | 340d |  | finish no earlier than 2003-09-17 | T3 | 2144h | 2144h |  |  | Mario Pérez (Microelectrónica Española) |  | Rel-6 |  |  |  |  |
| 286 | 39.1.3 | 2G/3G Java Card™ API based applet interworking | 191d | 2003-03-17 A | 2003-12-08 | 80% | 38.2d |  |  |  | 279d | finish no earlier than 2003-12-08 | T3 | 1528h | 1222.4h | USAT1-API |  | Stéphane Andrau-Oberthur Card Systems |  | Rel-6 | TSG | Claus |  |  |
| 287 | 39.2 | **Rel-6 USIM toolkit enhancements** | 525d | 2000-09-25 A | 2002-09-27 | 99% | 0d | 2000-09-25 | 2002-09-27 | 525d | 0d |  | T3 | 14160h | 10910h |  |  |  |  | Rel-6 |  | Claus |  |  |
| 288 | 39.2.1 | **C SIM API** | 525d | 2000-09-25 A | 2002-09-27 A | 100% |  | 2000-09-25 | 2002-09-27 | 525d |  |  | T3 | 9960h | 9960h | USAT1-API-MULTOS |  |  |  | Rel-6 | TSG |  | Ter | 2031 |
| 289 | 39.2.1.1 | Specification | 525d | 2000-09-25 A | 2002-09-27 A | 100% |  | 2000-09-25 | 2002-09-27 | 525d |  | finish no earlier than 2002-09-27 | T3 | 4200h | 4200h |  |  | Neil Livingston – Aspects Software |  | Rel-6 | TSG |  | Ter | 2032 |
| 290 | 39.2.1.2 | Test specification | 195d | 2001-01-01 A | 2001-09-28 A | 100% |  | 2001-01-01 | 2001-09-28 | 195d |  | finish no earlier than 2001-09-28 | T3 | 1560h | 1560h |  |  | Neil Livingston – Aspects Software |  | Rel-6 | TSG |  | Ter | 2033 |
| 291 | 40 | **Packet Switched Streaming Services Rel-6** | 349d? | 2002-11-18 A | 2004-03-18 | 44% | 194.38d? | 2002-11-18 | 2003-12-19 | 285d? | 206d |  | S4 | 6120h | 2711.34h | PSSrel6 |  | Olle Franceschi (Ericsson) | Olle.Franceschi@emp.ericsson.se | Rel-6 | TSG | Paolo |  |  |
| 292 | 40.1 | Stage 1 | 86d? | 2002-11-18 A | 2003-03-17 | 80% | 17.2d? | 2002-11-18 | 2003-03-17 | 86d? | 469d | finish no earlier than 2003-03-17 | S1 | 688h | 550.4h |  | 22.233 |  |  | Rel-6 | TSG |  |  |  |
| 293 | 40.2 | Stage 3 | 330d? | 2002-12-13 A | 2004-03-18 | 35% | 214.5d? | 2002-12-13 | 2003-12-19 | 266d? | 206d | finish no earlier than 2004-03-18 | S4 | 2640h | 924h | PSSrel6 | 26.233, 26.234, 26.244, 26.245, 26.246 | Olle Franceschi (Ericsson) | Olle.Franceschi@emp.ericsson.se | Rel-6 | WG | Paolo |  |  |
| 294 | 41 | Network Domain Security; Authentication Framework (NDS/AF) | 481d? | 2002-02-15 A | 2003-12-19 | 10% | 432.9d? | 2002-02-15 | 2003-12-19 | 481d? | 270d | finish no earlier than 2003-12-19 | S3 | 3848h | 384.8h | SEC1-NDS-AF |  | Tommi Viitanen, Nokia | tommi.viitanen@nokia.com | Rel-6 | TSG |  |  |  |
| 295 | 42 | AMR-WB extension for high audio quality | 330d | 2002-12-13 A | 2004-03-18 | 35% | 214.5d | 2002-12-13 | 2003-09-26 | 206d | 206d | finish no earlier than 2004-03-18 | S4 | 2640h | 924h | AMRWB+ |  | Janne Vainio (Nokia) | janne.m.vainio@nokia.com | Rel-6 | TSG | Paolo |  |  |
| 296 | 43 | Single Antenna Receiver Interference Cancellation (SAIC) | 220.92d? | 2002-11-15 A | 2003-11-21 | 60% | 88.37d? | 2002-11-15 | 2003-11-21 | 220.92d? | 290d | finish no earlier than 2003-11-21 | GP; G1 | 3534.72h | 2120.83h | SAIC |  | Marc Grant, Cingular Wireless |  | Rel-6 | TSG |  |  |  |
| 297 | 44 | **Support of Conversational Services in A/Gb mode via the PS domain** | 406d? | 2003-02-07 A | 2004-08-27 | 9% | 368.87d? | 2003-02-07 | 2004-04-23 | 316d? | 90d |  | GP | 12792h | 707.33h | SCSAGB |  | David Bladsjö, Ericsson |  | Rel-6 | TSG |  |  |  |
| 298 | 44.1 | Creation of a TR | 206d? | 2003-02-07 A | 2003-11-21 | 40% | 123.6d? | 2003-02-07 | 2003-11-21 | 206d? | 290d | finish no earlier than 2003-11-21 | GP | 1648h | 659.2h | SCSAGB-TR |  | David Bladsjö, Ericsson |  | Rel-6 | TSG |  |  |  |
| 299 | 44.2 | Stage 2 | 111d? | 2003-11-21 | 2004-04-23 |  |  | 2003-11-21 | 2004-04-23 | 111d? | 180d | finish no earlier than 2004-04-23 | GP | 888h |  | SCSAGB-Stage2 |  | David Bladsjö, Ericsson |  | Rel-6 | TSG |  |  |  |
| 300 | 44.3 | Radio Channel Support | 146d? | 2004-02-06 | 2004-08-27 |  |  | 2004-02-06 | 2004-04-23 | 56d? | 90d | finish no earlier than 2004-08-27 | GP | 1168h |  | SCSAGB-RCS |  | David Bladsjö, Ericsson |  | Rel-6 | TSG |  |  |  |
| 301 | 44.4 | Definition of radio resource management functionality | 146d? | 2004-02-06 | 2004-08-27 |  |  | 2004-02-06 | 2004-04-23 | 56d? | 90d | finish no earlier than 2004-08-27 | GP; G2 | 2336h |  | SCSAGB-RRM |  | David Bladsjö, Ericsson |  | Rel-6 | TSG |  |  |  |
| 302 | 44.5 | PS Handover | 146d? | 2004-02-06 | 2004-08-27 |  |  | 2004-02-06 | 2004-04-23 | 56d? | 90d | finish no earlier than 2004-08-27 | GP | 1168h |  | SCSAGB-PSH |  | David Bladsjö, Ericsson |  | Rel-6 | TSG |  |  |  |
| 303 | 44.6 | Modifications to FLO | 146d? | 2004-02-06 | 2004-08-27 |  |  | 2004-02-06 | 2004-04-23 | 56d? | 90d | finish no earlier than 2004-08-27 | GP; G2 | 2336h |  | SCSAGB-FLO |  | David Bladsjö, Ericsson |  | Rel-6 | TSG |  |  |  |

Notes:
- 274: az: Changed Rapp.
- 283: 8/3/2001: test spec is based on R99 core spec, so deleted from Workplan
- 292: 2nd resp SA4
- 294: WID approved SA#19. Work started after FS approved SA#18
- 299: Not started
- 300: Not started
- 301: Not started
- 302: Not started
- 303: Not started

| ID | WBS | Task | Duration | Start | Finish | Complete | Remaining | Baseline start | Baseline finish | Baseline duration | Total slack | Constraint | Resources | Work | Actual work | Text1 | Text4 | Text6 | Text7 | Text8 | Text5 |
| --- | --- | --- | --- | --- | --- | --- | --- | --- | --- | --- | --- | --- | --- | --- | --- | --- | --- | --- | --- | --- | --- |
| 304 | 45 | **Enhancement of dialled service for CAMEL** | 199d | 2003-03-28 A | 2003-12-31 | 57% | 85.6d | 2003-03-28 | 2003-09-19 | 126d? | 262d |  | S1 | 3184h | 1814.4h | EDCAMEL | Craig Bishop, Samsung Electronics Research Institute | Rel-6 | TSG | Andrijana |  |
| 305 | 45.1 | Stages 2 and 3 | 199d | 2003-03-28 A | 2003-12-31 | 57% | 85.6d | 2003-03-28 | 2003-09-19 | 126d | 262d | finish no earlier than 2003-09-19 | N2 | 1592h | 907.2h |  |  | Rel-6 |  |  |  |
| 306 | 46 | Bandwidth and resource savings in CS networks | 199d? | 2003-06-23 A | 2004-03-25 | 20% | 159.2d? | 2003-06-23 | 2003-11-25 | 112d? | 201d | finish no earlier than 2004-03-25 | S2 | 1592h | 318.4h | CSSAVE |  | Rel-6 |  |  |  |
| 307 | 47 | FS on (U)SIM Security Reuse by Peripheral Devices on Local Interfaces | 127d? | 2003-07-03 A | 2003-12-26 | 5% | 120.65d? | 2003-07-03 | 2003-12-26 | 127d? | 265d | finish no earlier than 2003-12-26 | S3 | 1016h | 50.8h |  | Raziq Yaqub, Toshiba America Research Inc. | Rel-6 | TSG | Maurice | ryaqub@tari.toshiba.com |
| 308 | 48 | Key Management of group keys for Voice Group Call Services | 191d | 2003-09-26 A | 2004-06-18 | 5% | 181.45d |  |  |  | 140d | finish no earlier than 2004-06-18 | S3 | 1528h | 76.4h | SECGKYV | Benno Tietz, Vodafone D2 | Rel-6 | TSG | Maurice | benno.tietz@vodafone.com |
| 309 | 49 | **Multiple TBF in A/Gb mode** | 476d? | 2002-04-05 A | 2004-01-30 | 70% | 143.95d? | 2002-04-05 | 2004-01-30 | 476d? | 240d |  | GP; G2 | 34848h | 25944.6h | MULTBF | Gunnar Mildh, Ericsson | Rel-6 | TSG | Paolo |  |
| 310 | 49.1 | **Multiple TBF in A/Gb mode** | 366d? | 2002-04-05 A | 2003-08-29 | 99% | 0d? | 2002-04-05 | 2003-08-29 | 366d? | 0d |  | GP; G2 | 23424h | 21960h | MULTBF-Agbmode | Gunnar Mildh, Ericsson | Rel-6 | TSG |  |  |
| 311 | 49.1.1 | Multiple TBF Concept paper | 366d? | 2002-04-05 A | 2003-08-29 A | 100% |  | 2002-04-05 | 2003-08-29 | 366d? |  | finish no earlier than 2003-08-29 | GP; G2 | 5856h | 5856h |  |  | Rel-6 |  |  |  |
| 312 | 49.1.2 | Multiple TBF Stage 2 (43.064) CRs | 366d? | 2002-04-05 A | 2003-08-29 A | 100% |  | 2002-04-05 | 2003-08-29 | 366d? |  | finish no earlier than 2003-08-29 | GP; G2 | 5856h | 5856h |  |  | Rel-6 |  |  |  |
| 313 | 49.1.3 | Multiple TBF Stage 3 (44.060) CRs | 366d? | 2002-04-05 A | 2003-08-29 A | 100% |  | 2002-04-05 | 2003-08-29 | 366d? |  | finish no earlier than 2003-08-29 | GP; G2 | 5856h | 5856h |  |  | Rel-6 |  |  |  |
| 314 | 49.2 | Multiple TBF in A/Gb mode – MS testing | 476d? | 2002-04-05 | 2004-01-30 |  |  | 2002-04-05 | 2004-01-30 | 476d? | 240d | finish no earlier than 2004-01-30 | GP-G2 | 3808h |  | MULTBF-Testing | Gunnar Mildh, Ericsson | Rel-6 | TSG | Paolo |  |
| 315 | 50 | **Alignment between the test-regimes for GERAN capable MS** | 61d? | 2003-08-29 | 2003-11-21 |  |  |  |  |  | 290d |  | G3 | 976h |  | ALTERE | Toubassi, Ericsson | Rel-6 | TSG | Michael |  |
| 316 | 50.1 | Determine the controversial test cases in the different test regimes and align them with 3GPP GERAN test specifications. Such test cases to be added to TS 51.010. | 61d? | 2003-08-29 | 2003-11-21 |  |  |  |  |  | 290d | start no earlier than 2003-08-29 | G3 | 488h |  | ALTERE-TC |  | Rel-6 | TSG |  |  |

Notes:
- 306: Text3: TR 23.977
- 307: Approved TSG#20
- 308: Approved TSG#21 / Text3: 42.068, 43.068, 44.068, 42.069, 43.069, 44.069, 31.102, 24.008, 48.008, 42.009, 43.020
- 313: Not started
